# AIP Cryo April 1

Schedule from MS Project, 2013-06-03 to 2017-06-22, status date 2014-09-30, costs in $, A marks actual dates.
Fermilab

## Calendars

- Standard: Mon-Fri 08:00-12:00, 13:00-17:00; Sat-Sun off. Exceptions (off unless hours are given): 2013-07-04 (Independence Day), 2013-09-02 (Labor Day), 2013-11-28 to 2013-11-29 (Thanksgiving), 2013-12-24 to 2013-12-25 (Christmas), 2013-12-31 to 2014-01-01 (New Years), 2014-01-20 (Martin Luther King Day), 2014-05-26 (Memorial Day), 2014-07-04 (Independence Day), 2014-09-01 (Labor Day), 2014-11-27 to 2014-11-28 (Thanksgiving), 2014-12-24 to 2014-12-25 (Christmas), 2014-12-31 to 2015-01-01 (New Years), 2015-01-19 (Martin Luther King Day), 2015-05-25 (Memorial Day), 2015-07-03 (Independence Day), 2015-09-07 to 2015-09-08 (Labor Day), 2015-11-26 to 2015-11-27 (Thanksgiving), 2015-12-24 to 2015-12-25 (Christmas), 2015-12-31 to 2016-01-01 (New Years), 2016-01-18 (Martin Luther King Day), 2016-05-30 (Memorial Day), 2016-07-04 (Independence Day), 2016-09-05 (Labor Day), 2016-11-24 to 2016-11-25 (Thanksgiving), 2016-12-23 to 2016-12-26 (Christmas), 2016-12-30 to 2017-01-02 (New Years), 2017-01-16 (Martin Luther King Day), 2017-05-29 (Memorial Day).

## Resources

| Resource | Group | Rate |
| --- | --- | --- |
| FNAD_CRYO_EN | AD | 42.94 |
| FNAD_CRYO_TECH | AD | 30.89 |
| FNAD_CRYO_SR | AD | 59.74 |
| FNAD_MECH_DRAFTER | AD | 28.88 |
| FNAD_PRJ_CTRL_MNGR | AD | 72 |
| FN_MS_STND_FY13 |  |  |
| FN_MS_EXMP_FY13 |  |  |

## Schedule

| ID | WBS | Task | Type | Duration | Start | Finish | Predecessors | Complete | Remaining | Baseline start | Baseline finish | Baseline duration | Total slack | Free slack | Constraint | Work | Actual work | Cost | Baseline cost | Actual cost | Cobra WBS # | Text20 |
| --- | --- | --- | --- | --- | --- | --- | --- | --- | --- | --- | --- | --- | --- | --- | --- | --- | --- | --- | --- | --- | --- | --- |
| 1 | Cryo1 | **Muon Campus Cryogenics - AIP** |  | 1018d | 2013-06-03 A | 2017-06-22 |  | 59% | 412.98d | 2013-06-03 | 2017-06-22 | 1018d | 0d |  |  | 33259h | 18048.8h | 3,778,010.05 | 3,791,947.75 | 2,253,927.81 | Cryo1 |  |
| 2 | Cryo1.01 | **Cryo AIP Milestones** |  | 1018d | 2013-06-03 A | 2017-06-22 |  |  | 1018d | 2013-06-03 | 2017-06-22 | 1018d | 0d |  |  |  |  |  |  |  | Cryo1.01 |  |
| 3 | Cryo1.01.01 | **Cryo AIP Management Milestones** |  | 1018d | 2013-06-03 A | 2017-06-22 |  |  | 1018d | 2013-06-03 | 2017-06-22 | 1018d | 0d |  |  |  |  |  |  |  |  |  |
| 4 | Cryo1.01.01.01 | FY13 funding | milestone | 0d | 2013-06-03 A | 2013-06-03 A |  | 100% |  | 2013-06-03 | 2013-06-03 | 0d |  |  | start no earlier than 2013-06-03 |  |  |  |  |  |  |  |
| 5 | Cryo1.01.01.02 | FY14 funding | milestone | 0d | 2013-10-01 A | 2013-10-01 A |  | 100% |  | 2013-10-01 | 2013-10-01 | 0d |  |  | start no earlier than 2013-10-01 |  |  |  |  |  |  |  |
| 6 | Cryo1.01.01.03 | FY15 funding | milestone | 0d | 2014-10-01 | 2014-10-01 |  |  |  | 2014-10-01 | 2014-10-01 | 0d | 192d | 0d | start no earlier than 2014-10-01 |  |  |  |  |  |  |  |
| 7 | Cryo1.01.01.04 | Start of Cryo AIP Project | milestone | 0d | 2013-06-17 A | 2013-06-17 A | 4 | 100% |  | 2013-06-17 | 2013-06-17 | 0d |  |  | start no earlier than 2013-06-17 |  |  |  |  |  |  |  |
| 8 | Cryo1.01.01.05 | g-2 Cold (g-2 Interface) - Target | milestone | 0d | 2015-01-21 | 2015-01-21 | 72, 89, 93, 102FS+20d, 110, 165, 79, 171, 212, 238, 239, 38, 24, 184, 235, 158 |  |  | 2015-01-02 | 2015-01-02 | 0d | -12d | 0d | finish no later than 2015-01-02 |  |  |  |  |  |  |  |
| 9 | Cryo1.01.01.06 | Finish Cryo AIP Project | milestone | 0d | 2017-06-22 | 2017-06-22 | 34, 157 |  |  | 2017-06-22 | 2017-06-22 | 0d | 0d |  |  |  |  |  |  |  |  |  |
| 10 | Cryo1.01.01.07 | FY16 Funding | milestone | 0d | 2015-10-01 | 2015-10-01 |  |  |  | 2015-10-01 | 2015-10-01 | 0d | 22d | 0d | start no earlier than 2015-10-01 |  |  |  |  |  |  |  |
| 11 | Cryo1.01.01.08 | FY17 Funding | milestone | 0d | 2016-10-03 | 2016-10-03 |  |  |  | 2016-10-03 | 2016-10-03 | 0d | 181d |  | start no earlier than 2016-10-03 |  |  |  |  |  |  |  |
| 12 | Cryo1.01.02 | **Interface milestones** |  | 847d | 2014-01-08 A | 2017-05-22 |  |  | 847d | 2014-01-08 | 2017-05-22 | 847d | 22d |  |  |  |  |  |  |  |  |  |
| 13 | Cryo1.01.02.01 | MC-1 Bldg Beneficial Occupancy for Cryo (MC-1 Building GPP Interface) | milestone | 0d | 2014-01-08 A | 2014-01-08 A |  | 100% |  | 2014-01-08 | 2014-01-08 | 0d |  |  | start no earlier than 2014-01-08 |  |  |  |  |  |  | Do we have a target date for this? |
| 14 | Cryo1.01.02.02 | A0 to MC1 Header Supports Ready (MC-1 Building GPP Interface) | milestone | 0d | 2014-01-08 A | 2014-01-08 A | 13 | 100% |  | 2014-01-08 | 2014-01-08 | 0d |  |  | start no earlier than 2014-01-08 |  |  |  |  |  |  | Need successor, any other predecessors? |
| 15 | Cryo1.01.02.03 | High Bay Beneficial Occupancy | milestone | 0d | 2014-04-10 A | 2014-04-10 A |  | 100% |  | 2014-04-15 | 2014-04-15 | 0d |  |  | start no earlier than 2014-04-10 |  |  |  |  |  |  |  |
| 16 | Cryo1.01.02.04 | Cryo Ready to Cool g-2 | milestone | 0d | 2015-03-10 | 2015-03-10 | 8FS+34d, 75 |  |  | 2015-02-20 | 2015-02-20 | 0d | 3d |  | finish no later than 2015-03-15 |  |  |  |  |  |  |  |
| 17 | Cryo1.01.02.05 | Cryo Mu2e Distribution Box Cold (Mu2e Interface) | milestone | 0d | 2017-05-22 | 2017-05-22 | 228, 234, 240 |  |  | 2017-05-22 | 2017-05-22 | 0d | 22d |  | finish no later than 2017-07-15 |  |  |  |  |  |  |  |
| 18 | Cryo1.01.02.06 | MC-1 Cryo Controls Room Available | milestone | 0d | 2014-09-22 A | 2014-09-22 A |  | 100% |  | 2014-09-22 | 2014-09-22 | 0d |  |  | start no earlier than 2014-09-22 |  |  |  |  |  |  |  |
| 19 | Cryo1.01.02.07 | Cryo Compressor Cooling Established | milestone | 0d | 2014-06-02 A | 2014-06-02 A | 171FF+2d | 100% |  | 2014-09-23 | 2014-09-23 | 0d |  |  | finish no later than 2014-09-30 |  |  |  |  |  |  |  |
| 20 | Cryo1.01.03 | **Project Plan Milestones** |  | 726d | 2014-07-31 A | 2017-06-22 |  |  | 726d | 2014-07-03 | 2017-06-22 | 745d | 0d |  |  |  |  |  |  |  |  |  |
| 21 | Cryo1.01.03.01 | Begin Refrigeration Installation | milestone | 0d | 2014-07-31 A | 2014-07-31 A | 91SS | 100% |  | 2014-07-03 | 2014-07-03 | 0d |  |  | start no earlier than 2014-01-03 |  |  |  |  |  |  |  |
| 22 | Cryo1.01.03.02 | Compressor System Ready | milestone | 0d | 2014-09-15 A | 2014-09-15 A | 182, 173, 175 | 100% |  | 2014-09-15 | 2014-09-15 | 0d |  |  | start no earlier than 2014-09-15 |  |  |  |  |  |  |  |
| 23 | Cryo1.01.03.03 | Refrigeration System Ready | milestone | 0d | 2014-10-21 | 2014-10-21 | 116, 102FS+15d |  |  | 2014-10-30 | 2014-10-30 | 0d | 7d | 0d |  |  |  |  |  |  |  |  |
| 24 | Cryo1.01.03.04 | Muon g-2 Acceptance Tests Complete | milestone | 0d | 2014-12-18 | 2014-12-18 | 22, 239 |  |  | 2015-01-02 | 2015-01-02 | 0d | 7d |  |  |  |  |  |  |  |  |  |
| 25 | Cryo1.01.03.05 | System Engineering Complete | milestone | 0d | 2017-05-26 | 2017-05-26 | 41, 42, 43 |  |  | 2017-05-26 | 2017-05-26 | 0d | 18d |  | start no earlier than 2017-02-28 |  |  |  |  |  |  |  |
| 26 | Cryo1.01.03.06 | Mu2e Acceptance Tests Complete | milestone | 0d | 2017-04-24 | 2017-04-24 | 237 |  |  | 2017-04-24 | 2017-04-24 | 0d | 42d |  |  |  |  |  |  |  |  |  |
| 27 | Cryo1.01.03.07 | Project Complete | milestone | 0d | 2017-06-22 | 2017-06-22 | 9 |  |  | 2017-06-22 | 2017-06-22 | 0d | 0d |  |  |  |  |  |  |  |  |  |

| ID | WBS | Task | Type | Duration | Start | Finish | Predecessors | Complete | Remaining | Baseline start | Baseline finish | Baseline duration | Total slack | Free slack | Constraint | Resources | Work | Actual work | Cost | Baseline cost | Actual cost | BOE File Name | BOE Number | Cobra WBS # | CTC + Name | Cobra WP ID | Text20 | CTC | Misc | CR# |
| --- | --- | --- | --- | --- | --- | --- | --- | --- | --- | --- | --- | --- | --- | --- | --- | --- | --- | --- | --- | --- | --- | --- | --- | --- | --- | --- | --- | --- | --- | --- |
| 28 | Cryo1.02 | **Cryo Project Management** |  | 1008d | 2013-06-17 A | 2017-06-22 |  | 32% | 684d | 2013-06-17 | 2017-06-22 | 1008d | 0d |  |  |  | 2625h | 865.96h | 264,024.35 | 264,024.3 | 84,141.7 | +Cryo Project Management BOE | Beams 4395 | Cryo1.02 |  |  |  |  |  |  |
| 29 | Cryo1.02.01 | **General Project OS** |  | 1008d | 2013-06-17 A | 2017-06-22 |  | 32% | 684d | 2013-06-17 | 2017-06-22 | 1008d | 0d |  |  |  | 2625h | 865.96h | 264,024.35 | 264,024.3 | 84,141.7 | +Cryo Project Management BOE | Beams 4395 | Cryo1.02.01 |  |  |  |  |  |  |
| 30 | Cryo1.02.01.01 | Cryo AIP General Project OS - FY13 |  | 68d | 2013-06-17 A | 2013-09-20 A | 7 | 100% |  | 2013-06-17 | 2013-09-20 | 68d |  |  | start no earlier than 2012-10-01 | FNAD_PRJ_CTRL_MNGR [15.1%]; FNAD_CRYO_EN [51.4%]; FNAD_CRYO_SR [3.6%]; FN_MS_STND_FY13 [500000%] | 266h | 266h | 19,486.42 | 19,485.82 | 19,486.42 | +Cryo Project Management BOE | Beams 4395 | Cryo1.02.01.01 | A1301.02.01.01 - Cryo AIP General Project OS - FY13 | 2361 | Need new start/predecessor | A1301.02.01.01 |  |  |
| 31 | Cryo1.02.01.02 | Cryo AIP General Project OS - FY14 |  | 251d | 2013-09-23 A | 2014-09-22 A | 30 | 100% |  | 2013-09-23 | 2014-09-22 | 251d |  |  |  | FNAD_CRYO_SR [11.9%]; FNAD_CRYO_EN [17.4%]; FN_MS_STND_FY13 | 588h | 588h | 63,378.39 | 68,729.1 | 63,378.39 | +Cryo Project Management BOE | Beams 4395 | Cryo1.02.01.02 | A1301.02.01.02 - Cryo AIP General Project OS - FY14 | 2755 |  | A1301.02.01.02 |  |  |
| 32 | Cryo1.02.01.03 | Cryo AIP General Project OS - FY15 |  | 250d | 2014-09-23 A | 2015-09-22 | 31 | 2% | 245d | 2014-09-23 | 2015-09-22 | 250d | 0d |  |  | FNAD_CRYO_SR [1.2%]; FN_MS_STND_FY13 | 24h | 0.48h | 63,844.52 | 63,844.52 | 1,276.89 | +Cryo Project Management BOE | Beams 4395 | Cryo1.02.01.03 | A1301.02.01.03 - Cryo AIP General Project OS - FY15 | 2756 |  | A1301.02.01.03 | ***Charge Code*** | CR008 |
| 33 | Cryo1.02.01.04 | Cryo AIP General Project OS - FY16 |  | 252d | 2015-09-23 | 2016-09-22 | 32 |  |  | 2015-09-23 | 2016-09-22 | 252d | 0d |  |  | FNAD_CRYO_SR [12.5%]; FNAD_CRYO_EN [17.4%]; FN_MS_STND_FY13 | 601h |  | 64,023.74 | 64,023.74 |  | +Cryo Project Management BOE | Beams 4395 | Cryo1.02.01.04 | A1301.02.01.04 - Cryo AIP General Project OS - FY16 | 2757 |  | A1301.02.01.04 | ***Charge Code*** |  |
| 34 | Cryo1.02.01.05 | Cryo AIP General Project OS - FY17 |  | 187d | 2016-09-23 | 2017-06-22 | 33 |  |  | 2016-09-23 | 2017-06-22 | 187d | 0d |  |  | FNAD_CRYO_SR [14.8%]; FNAD_CRYO_EN [23.4%]; FN_MS_STND_FY13 | 572h |  | 53,291.28 | 53,291.28 |  | +Cryo Project Management BOE | Beams 4395 | Cryo1.02.01.05 | A1301.02.01.05 - Cryo AIP General Project OS - FY17 | 2758 |  | A1301.02.01.05 | ***Charge Code*** |  |
| 35 | Cryo1.03 | **Cryo Basic Engineering** |  | 990d | 2013-06-17 A | 2017-05-26 |  | 21% | 785d | 2013-06-17 | 2017-05-26 | 990d | 18d |  |  |  | 3716h | 2196h | 151,596.21 | 151,595.89 | 86,327.41 | +Cryo Basic Engineering BOE | Beams 4395 | Cryo1.03 |  |  |  | A1301.03 |  |  |
| 36 | Cryo1.03.01 | Basic Engineering Prel Work |  | 20d | 2013-06-17 A | 2013-07-15 A | 7 | 100% |  | 2013-06-17 | 2013-07-15 | 20d |  |  |  | FNAD_CRYO_EN [85%] | 136h | 136h | 6,979.52 | 6,979.52 | 6,979.52 | +Cryo Basic Engineering BOE | Beams 4395 | Cryo1.03 | A1301.03 - Cryo Basic Engineering | 2894 |  | A1301.03 |  |  |
| 37 | Cryo1.03.02 | Basic Eng Drafting |  | 250d | 2013-06-17 A | 2014-06-13 A | 7, 36SS | 100% |  | 2013-06-17 | 2014-06-13 | 250d |  |  | start no earlier than 2012-10-01 | FNAD_MECH_DRAFTER [28%] | 560h | 560h | 14,937.89 | 12,000.8 | 14,937.89 | +Cryo Basic Engineering BOE | Beams 4395 | Cryo1.03 | A1301.03 - Cryo Basic Engineering | 2497 | Need new start/predecessor | A1301.03 |  |  |
| 38 | Cryo1.03.03 | Basic engineering complete | milestone | 0d | 2014-09-30 A | 2014-09-30 A | 37, 39 | 100% |  | 2014-09-30 | 2014-09-30 | 0d |  |  |  |  |  |  |  |  |  |  |  |  |  |  | Successor? |  |  |  |
| 39 | Cryo1.03.04 | Basic Engineering OS |  | 251d | 2013-10-01 A | 2014-09-30 A | 5 | 100% |  | 2013-10-01 | 2014-09-30 | 251d |  |  |  | FNAD_CRYO_EN [74.7%] | 1500h | 1500h | 64,410 | 76,980 | 64,410 | +Cryo Basic Engineering BOE | Beams 4395 | Cryo1.03 | A1301.03 - Cryo Basic Engineering | 2832 |  | A1301.03 |  |  |
| 40 | Cryo1.03.05 | **Cryo Engineering** |  | 665d | 2014-10-01 | 2017-05-26 |  |  |  | 2014-10-01 | 2017-05-26 | 665d | 18d |  |  |  | 1520h |  | 65,268.8 | 65,268.8 |  | +Cryo Basic Engineering BOE | Beams 4395 | Cryo1.03 |  |  |  |  |  |  |
| 41 | Cryo1.03.05.01 | Cryo Mechanical Engineering |  | 665d | 2014-10-01 | 2017-05-26 | 38 |  |  | 2014-10-01 | 2017-05-26 | 665d | 18d | 0d | start no earlier than 2012-10-01 | FNAD_CRYO_EN [6%] | 320h |  | 13,740.8 | 13,740.8 |  | +Cryo Basic Engineering BOE | Beams 4395 | Cryo1.03 | A1301.03 - Cryo Basic Engineering | 989 | Need new start/predecessor | A1301.03 |  |  |
| 42 | Cryo1.03.05.02 | Cryo Controls Engineering |  | 665d | 2014-10-01 | 2017-05-26 | 38 |  |  | 2014-10-01 | 2017-05-26 | 665d | 18d | 0d |  | FNAD_CRYO_EN [15%] | 800h |  | 34,352 | 34,352 |  | +Cryo Basic Engineering BOE | Beams 4395 | Cryo1.03 | A1301.03 - Cryo Basic Engineering | 988 |  | A1301.03 |  |  |
| 43 | Cryo1.03.05.03 | Cryo Electrical Engineering |  | 665d | 2014-10-01 | 2017-05-26 | 38 |  |  | 2014-10-01 | 2017-05-26 | 665d | 18d | 0d |  | FNAD_CRYO_EN [7.5%] | 400h |  | 17,176 | 17,176 |  | +Cryo Basic Engineering BOE | Beams 4395 | Cryo1.03 | A1301.03 - Cryo Basic Engineering | 990 |  | A1301.03 |  |  |
| 44 | Cryo1.04 | **Cryogenic plant sub systems** |  | 656d | 2013-06-17 A | 2016-02-01 |  | 94% | 38.66d | 2013-06-17 | 2016-02-01 | 656d | 352d |  |  |  | 14728h | 13364h | 2,292,802.19 | 2,306,740.35 | 2,012,351.07 |  |  | Cryo1.04 |  |  |  |  |  |  |
| 45 | Cryo1.04.01 | **Cryo LN2 system** |  | 251d | 2013-08-30 A | 2014-08-29 A |  | 100% |  | 2013-08-30 | 2014-09-02 | 252d |  |  |  |  | 2456h | 2456h | 209,825.26 | 238,772.26 | 209,825.28 | +Cryo LN2 System BOE | Beams 4395 | Cryo1.04.01 |  |  |  | A1301.04.01 |  |  |
| 46 | Cryo1.04.01.01 | Basic Engineering - LN2 System |  | 61d | 2013-10-01 A | 2013-12-30 A | 5 | 100% |  | 2013-10-01 | 2014-01-06 | 64d |  |  | start no earlier than 2013-05-06 | FNAD_MECH_DRAFTER [4.5%] | 20h | 20h | 577.59 | 428.6 | 577.6 | +Cryo LN2 System BOE | Beams 4395 | Cryo1.04.01 | A1301.04.01 - Cryo LN2 system | 2421 |  | A1301.04.01 |  |  |
| 47 | Cryo1.04.01.02 | LN2 System Preparation |  | 82d | 2013-08-30 A | 2013-12-30 A | 48FF | 100% |  | 2013-08-30 | 2014-01-06 | 85d |  |  |  | FNAD_CRYO_EN [11.4%]; FNAD_CRYO_TECH [13.5%] | 148h | 148h | 5,493.96 | 5,809.76 | 5,493.96 | +Cryo LN2 System BOE | Beams 4395 | Cryo1.04.01 | A1301.04.01 - Cryo LN2 system | 2160 |  | A1301.04.01 |  |  |
| 48 | Cryo1.04.01.02 | Basic Engineering Complete - LN2 System | milestone | 0d | 2013-12-30 A | 2013-12-30 A | 46 | 100% |  | 2014-01-06 | 2014-01-06 | 0d |  |  |  |  |  |  |  |  |  |  |  |  |  |  |  |  |  |  |
| 49 | Cryo1.04.01.03 | LN2 System Procurement |  | 43d | 2013-10-01 A | 2013-12-02 A | 5 | 100% |  | 2013-10-01 | 2013-12-02 | 43d |  |  |  | FNAD_CRYO_TECH [7%]; FN_MS_STND_FY13 | 24h | 24h | 10,741.35 | 10,696 | 10,741.36 | +Cryo LN2 System BOE | Beams 4395 | Cryo1.04.01 | A1301.04.01 - Cryo LN2 system | 2838 |  | A1301.04.01 |  |  |
| 50 | Cryo1.04.01.04 | Fabrication - LN2 System |  | 61d | 2013-10-01 A | 2013-12-30 A | 46FF, 47FF | 100% |  | 2013-10-01 | 2014-01-06 | 64d |  |  |  | FNAD_CRYO_TECH [213.9%]; FN_MS_STND_FY13 | 960h | 960h | 49,654.4 | 47,840 | 49,654.4 | +Cryo LN2 System BOE | Beams 4395 | Cryo1.04.01 | A1301.04.01 - Cryo LN2 system | 2620 |  | A1301.04.01 |  |  |
| 51 | Cryo1.04.01.05 | Warm Weather Available for CHL Dewar Work | milestone | 0d | 2014-05-08 A | 2014-05-08 A |  | 100% |  | 2014-05-08 | 2014-05-08 | 0d |  |  | start no earlier than 2014-05-08 |  |  |  |  |  |  |  |  |  |  |  |  |  |  |  |
| 52 | Cryo1.04.01.06 | Indoor Installation - LN2 System |  | 27d | 2014-01-30 A | 2014-03-07 A | 50, 13FS+15d, 49 | 100% |  | 2014-01-30 | 2014-02-28 | 22d |  |  |  | FNAD_CRYO_TECH [231.5%]; FN_MS_STND_FY13 | 500h | 500h | 35,445 | 33,591.6 | 35,445 | +Cryo LN2 System BOE | Beams 4395 | Cryo1.04.01 | A1301.04.01 - Cryo LN2 system | 2839 |  | A1301.04.01 |  |  |
| 53 | Cryo1.04.01.07 | Preparing of LN2 dewar at CHL |  | 15d | 2014-05-08 A | 2014-05-29 A | 51 | 100% |  | 2014-05-08 | 2014-05-29 | 15d |  |  |  | FNAD_CRYO_TECH [16.7%] | 20h | 20h | 617.8 | 617.8 | 617.8 |  |  | Cryo1.04.01 | A1301.04.01 - Cryo LN2 system | 2902 |  | A1301.04.01 |  | CR002 |
| 54 | Cryo1.04.01.08 | Rigging of LN2 dewar from CHL to MC-1 |  | 1d | 2014-05-30 A | 2014-05-30 A | 53 | 100% |  | 2014-05-30 | 2014-06-03 | 3d |  |  |  | FNAD_CRYO_TECH [375%] | 30h | 30h | 926.7 | 926.7 | 926.7 |  |  | Cryo1.04.01 | A1301.04.01 - Cryo LN2 system | 2904 |  | A1301.04.01 |  | CR002 |
| 55 | Cryo1.04.01.09 | Outdoor Installation - LN2 System |  | 25d | 2014-06-03 A | 2014-07-08 A | 84FS+90d, 54 | 100% |  | 2014-06-04 | 2014-07-09 | 25d |  |  |  | FNAD_CRYO_TECH [125%]; FN_MS_STND_FY13 | 250h | 250h | 88,775.5 | 117,722.5 | 88,775.5 | +Cryo LN2 System BOE | Beams 4395 | Cryo1.04.01 | A1301.04.01 - Cryo LN2 system | 2499 | Need to detail the procurement. | A1301.04.01 |  | CR002, CR005 |
| 56 | Cryo1.04.01.10 | LN2 ORC |  | 38d | 2014-07-09 A | 2014-08-29 A | 55 | 100% |  | 2014-07-09 | 2014-07-09 | 0d |  |  |  |  |  |  |  |  |  |  |  |  |  |  |  |  |  |  |
| 57 | Cryo1.04.01.11 | LN2 Checkout |  | 20d | 2014-08-04 A | 2014-08-29 A | 55, 52, 53FS+45d | 100% |  | 2014-08-04 | 2014-09-02 | 21d |  |  |  | FNAD_CRYO_TECH [210%]; FNAD_CRYO_EN [105%] | 504h | 504h | 17,592.96 | 17,592.96 | 17,592.96 | +Cryo LN2 System BOE | Beams 4395 | Cryo1.04.01 | A1301.04.01 - Cryo LN2 system | 2841 |  | A1301.04.01 |  |  |
| 58 | Cryo1.04.01.12 | LN2 system is complete | milestone | 0d | 2014-08-29 A | 2014-08-29 A | 56, 57 | 100% |  | 2014-09-02 | 2014-09-02 | 0d |  |  |  |  |  |  |  |  |  |  |  |  |  |  |  |  |  |  |

Notes:
- 55: 900 hours of rigging + misc M&S

| ID | WBS | Task | Type | Duration | Start | Finish | Predecessors | Complete | Remaining | Baseline start | Baseline finish | Baseline duration | Total slack | Constraint | Resources | Work | Actual work | Cost | Baseline cost | Actual cost | BOE File Name | BOE Number | Cobra WBS # | CTC | CTC + Name | Cobra WP ID | CR# |
| --- | --- | --- | --- | --- | --- | --- | --- | --- | --- | --- | --- | --- | --- | --- | --- | --- | --- | --- | --- | --- | --- | --- | --- | --- | --- | --- | --- |
| 59 | Cryo1.04.02 | **Cryo Gas management system** |  | 270d | 2013-06-17 A | 2014-07-14 A |  | 100% |  | 2013-06-17 | 2014-07-14 | 270d |  |  |  | 368h | 368h | 170,830.49 | 170,830.49 | 170,830.49 | +Cryo Gas Management System BOE | Beams 4395 | Cryo1.04.02 | A1301.04.02 |  |  |  |
| 60 | Cryo1.04.02.01 | Prep Req & Process PO - GMS Valves & Components |  | 127d | 2013-06-27 A | 2013-12-30 A |  | 100% |  | 2013-06-27 | 2014-02-18 | 160d |  | start no earlier than 2013-06-27 | FNAD_CRYO_TECH [1.6%] | 8h | 8h | 240.78 | 232 | 240.78 | +Cryo Gas Management System BOE | Beams 4395 | Cryo1.04.02 | A1301.04.02 | A1301.04.02 - Cryo Gas management system | 2585 |  |
| 61 | Cryo1.04.02.02 | 1st Award - GMS Valves & Components |  | 0.12d | 2013-08-27 A | 2013-08-27 A | 60SS+42d | 100% |  | 2013-08-27 | 2013-08-27 | 0.12d |  |  |  |  |  |  |  |  | +Cryo Gas Management System BOE | Beams 4395 | Cryo1.04.02 | A1301.04.02 | A1301.04.02 - Cryo Gas management system | 2586 |  |
| 62 | Cryo1.04.02.03 | 1st Delivery - GMS Valves & Components |  | 42d | 2013-08-30 A | 2013-10-30 A | 61FF+45d | 100% |  | 2013-08-30 | 2013-10-30 | 42d |  |  | FN_MS_STND_FY13 |  |  | 20,964 | 20,964 | 20,964 | +Cryo Gas Management System BOE | Beams 4395 | Cryo1.04.02 | A1301.04.02 | A1301.04.02 - Cryo Gas management system | 2587 |  |
| 63 | Cryo1.04.02.04 | 2nd Award - GMS Tank Farm Valves & Components |  | 102d | 2013-10-01 A | 2014-02-28 A | 60FF+20d, 5 | 100% |  | 2013-10-01 | 2014-03-26 | 120d |  | finish no earlier than 2014-02-28 |  |  |  |  |  |  | +Cryo Gas Management System BOE | Beams 4395 | Cryo1.04.02 | A1301.04.02 | A1301.04.02 - Cryo Gas management system | 2588 |  |
| 64 | Cryo1.04.02.05 | 2nd Delivery - GMS Tank Farm Valves & Components |  | 75d | 2013-10-15 A | 2014-02-05 A | 63SS+10d | 100% |  | 2013-10-15 | 2014-05-21 | 150d |  |  | FN_MS_STND_FY13 |  |  | 65,000 | 65,000 | 65,000 | +Cryo Gas Management System BOE | Beams 4395 | Cryo1.04.02 | A1301.04.02 | A1301.04.02 - Cryo Gas management system | 2589 |  |
| 65 | Cryo1.04.02.06 | Interconnect Piping Award A0 Inventory Control Piping |  | 0.12d | 2013-08-30 A | 2013-08-30 A | 186FS+5d | 100% |  | 2013-08-30 | 2013-08-30 | 0.12d |  |  |  |  |  |  |  |  | +Cryo Interconnect Piping BOE | Beams 4395 | Cryo1.04.02 | A1301.04.02 | A1301.04.02 - Cryo Gas management system | 2895 |  |
| 66 | Cryo1.04.02.07 | Interconnect Piping Deliver & Install A0 Inventory Control Piping |  | 60d | 2013-08-30 A | 2013-11-25 A | 65 | 100% |  | 2013-08-30 | 2013-11-25 | 60d |  |  | FN_MS_STND_FY13 |  |  | 70,000 | 70,000 | 70,000 | +Cryo Interconnect Piping BOE | Beams 4395 | Cryo1.04.02 | A1301.04.02 | A1301.04.02 - Cryo Gas management system | 2896 |  |
| 67 | Cryo1.04.02.08 | Task Management - GMS |  | 62d | 2013-09-17 A | 2013-12-13 A | 69SS-10d | 100% |  | 2013-09-17 | 2013-12-13 | 62d |  |  | FNAD_CRYO_TECH [16.1%]; FNAD_CRYO_EN [10.5%] | 132h | 132h | 4,749.59 | 4,988.64 | 4,749.59 | +Cryo Gas Management System BOE | Beams 4395 | Cryo1.04.02 | A1301.04.02 | A1301.04.02 - Cryo Gas management system | 2624 |  |
| 68 | Cryo1.04.02.09 | Fabrication - GMS |  | 15d | 2013-06-17 A | 2013-07-08 A | 4FS+10d | 100% |  | 2013-06-17 | 2013-07-08 | 15d |  |  | FNAD_CRYO_TECH [66.7%]; FNAD_CRYO_EN [33.3%] | 120h | 120h | 4,370.4 | 4,372.8 | 4,370.4 | +Cryo Gas Management System BOE | Beams 4395 | Cryo1.04.02 | A1301.04.02 | A1301.04.02 - Cryo Gas management system | 2604 |  |
| 69 | Cryo1.04.02.10 | Installation - GMS |  | 57d | 2013-10-01 A | 2013-12-20 A | 62FF, 68FF, 5 | 100% |  | 2013-10-01 | 2013-12-20 | 57d |  |  | FNAD_CRYO_TECH [9.6%]; FN_MS_STND_FY13 [178400%] | 44h | 44h | 3,143.16 | 3,060 | 3,143.16 | +Cryo Gas Management System BOE | Beams 4395 | Cryo1.04.02 | A1301.04.02 | A1301.04.02 - Cryo Gas management system | 2584 |  |
| 70 | Cryo1.04.02.11 | Installed - GMS | milestone | 0d | 2013-12-20 A | 2013-12-20 A | 69 | 100% |  | 2013-12-20 | 2013-12-20 | 0d |  |  |  |  |  |  |  |  |  |  |  |  |  |  |  |
| 71 | Cryo1.04.02.12 | Checkout - GMS |  | 4d | 2014-07-09 A | 2014-07-14 A | 69FS+135d, 64FF | 100% |  | 2014-07-09 | 2014-07-14 | 4d |  |  | FNAD_CRYO_TECH; FNAD_CRYO_EN | 64h | 64h | 2,362.56 | 2,362.56 | 2,362.56 |  |  | Cryo1.04.02 | A1301.04.02 | A1301.04.02 - Cryo Gas management system | 2842 |  |
| 72 | Cryo1.04.02.13 | GMS is complete | milestone | 0d | 2013-12-30 A | 2013-12-30 A | 71, 67, 70 | 100% |  | 2014-01-02 | 2014-01-02 | 0d |  |  |  |  |  |  |  |  |  |  |  |  |  |  |  |
| 73 | Cryo1.04.03 | **Cryo ODH system** |  | 79d | 2014-05-05 A | 2014-08-25 A |  | 100% |  | 2014-05-05 | 2014-08-26 | 80d |  |  |  | 58h | 58h | 37,056.72 | 37,056.72 | 37,056.72 | +Cryo ODH System BOE | Beams 4395 | Cryo1.04.03 | A1301.04.03 |  |  |  |
| 74 | Cryo1.04.03.01 | Procure ODH Equipment |  | 19d | 2014-05-05 A | 2014-05-30 A | 5FS+147d | 100% |  | 2014-05-05 | 2014-06-02 | 20d |  |  | FNAD_CRYO_TECH [10.5%]; FN_MS_STND_FY13 | 16h | 16h | 30,494.24 | 30,494.24 | 30,494.24 | +Cryo ODH System BOE | Beams 4395 | Cryo1.04.03 | A1301.04.03 | A1301.04.03 - Cryo ODH system | 2582 |  |
| 75 | Cryo1.04.03.02 | Install ODH Equipment |  | 60d | 2014-06-02 A | 2014-08-25 A | 74FF+60d | 100% |  | 2014-06-03 | 2014-08-26 | 60d |  |  | FNAD_CRYO_TECH [4.2%]; FNAD_CRYO_EN [4.6%]; FN_MS_STND_FY13 [500000%] | 42h | 42h | 6,562.48 | 6,562.48 | 6,562.48 | +Cryo ODH System BOE | Beams 4395 | Cryo1.04.03 | A1301.04.03 | A1301.04.03 - Cryo ODH system | 2583 | CR002 |
| 76 | Cryo1.04.04 | **Cryo Refrigerator System** |  | 656d | 2013-06-17 A | 2016-02-01 |  | 88% | 76.79d | 2013-06-17 | 2016-02-01 | 656d | 352d | start no earlier than 2012-11-05 |  | 7136h | 5772h | 1,040,249.59 | 968,651.54 | 759,798.45 | +Cryo Refrigeration System BOE | Beams 4395 | Cryo1.04.04 | A1301.04.04 |  |  |  |
| 77 | Cryo1.04.04.01 | **Refrigerator System U-tubes** |  | 20d | 2014-08-11 A | 2014-09-08 A |  | 100% |  | 2014-08-11 | 2014-09-08 | 20d |  |  |  | 276h | 276h | 38,177.84 | 38,177.84 | 38,177.84 | +Cryo Refrigeration System BOE | Beams 4395 |  |  |  |  |  |
| 78 | Cryo1.04.04.01.01 | Design & Fabricate U-tubes |  | 20d | 2014-08-11 A | 2014-09-08 A | 5FS+215d | 100% |  | 2014-08-11 | 2014-09-08 | 20d |  |  | FNAD_MECH_DRAFTER [50%]; FNAD_CRYO_TECH [85%]; FNAD_CRYO_EN [37.5%]; FN_MS_STND_FY13 | 276h | 276h | 38,177.84 | 38,177.84 | 38,177.84 | +Cryo Refrigeration System BOE | Beams 4395 | Cryo1.04.04 | A1301.04.04 | A1301.04.04 - Cryo Refrigerator System | 2725 | CR002 |
| 79 | Cryo1.04.04.01.02 | U-tubes Complete | milestone | 0d | 2014-09-08 A | 2014-09-08 A | 78 | 100% |  | 2014-09-08 | 2014-09-08 | 0d |  |  |  |  |  |  |  |  |  |  |  |  |  |  |  |
| 80 | Cryo1.04.04.02 | **Refrig Syst Heat exchangers** |  | 222d | 2013-09-17 A | 2014-08-05 A |  | 100% |  | 2013-09-17 | 2014-08-06 | 223d |  |  |  | 1006h | 1006h | 59,063.27 | 56,388.27 | 59,063.27 | +Cryo Refrigeration System BOE | Beams 4395 | Cryo1.04.04 |  |  |  |  |
| 81 | Cryo1.04.04.02.01 | **Prep Heat Exchangers for Installation** |  | 222d | 2013-09-17 A | 2014-08-05 A |  | 100% |  | 2013-09-17 | 2014-08-06 | 223d |  |  |  | 1006h | 1006h | 59,063.27 | 56,388.27 | 59,063.27 | +Cryo Refrigeration System BOE | Beams 4395 |  |  |  |  |  |
| 82 | Cryo1.04.04.02.01.01 | Prep Heat Exchangers & Test |  | 67d | 2013-09-17 A | 2013-12-20 A | 7FS+64d | 100% |  | 2013-09-17 | 2013-12-20 | 67d |  |  | FNAD_CRYO_TECH [110.1%] | 590h | 590h | 18,056.03 | 17,110 | 18,056.03 | +Cryo Refrigeration System BOE | Beams 4395 | Cryo1.04.04 | A1301.04.04 | A1301.04.04 - Cryo Refrigerator System | 1269 |  |
| 83 | Cryo1.04.04.02.01.02 | Heat Exchanger Procurement |  | 61d | 2013-10-01 A | 2013-12-30 A | 5 | 100% |  | 2013-10-01 | 2014-01-09 | 67d |  |  | FNAD_CRYO_TECH [3.8%]; FN_MS_STND_FY13 | 16h | 16h | 10,494.24 | 10,464 | 10,494.24 |  |  | Cryo1.04.04 | A1301.04.04 | A1301.04.04 - Cryo Refrigerator System | 2843 |  |
| 84 | Cryo1.04.04.02.01.03 | Heat Exchanger Rigging |  | 10d | 2014-01-10 A | 2014-01-24 A | 13FS+2d, 82, 83 | 100% |  | 2014-01-10 | 2014-01-24 | 10d |  |  | FNAD_CRYO_EN [50%]; FN_MS_STND_FY13 | 40h | 40h | 16,717.6 | 17,052.8 | 16,717.6 |  |  | Cryo1.04.04 | A1301.04.04 | A1301.04.04 - Cryo Refrigerator System | 2844 |  |
| 85 | Cryo1.04.04.02.01.04 | Heat Exchanger Suction Parallel Plate Installation |  | 12d | 2014-02-13 A | 2014-02-28 A | 84FS+13d | 100% |  | 2014-02-13 | 2014-03-05 | 15d |  |  | FNAD_CRYO_TECH [125%] | 120h | 120h | 3,706.8 | 3,706.8 | 3,706.8 |  |  | Cryo1.04.04 | A1301.04.04 | A1301.04.04 - Cryo Refrigerator System | 2906 | CR002 |
| 86 | Cryo1.04.04.02.01.05 | Heat Exchangers Recondition Valves |  | 10d | 2014-02-17 A | 2014-02-28 A | 85FF | 100% |  | 2014-03-06 | 2014-03-19 | 10d |  |  | FNAD_CRYO_TECH | 80h | 80h | 2,471.2 | 2,471.2 | 2,471.2 |  |  | Cryo1.04.04 | A1301.04.04 | A1301.04.04 - Cryo Refrigerator System | 2905 | CR002 |
| 87 | Cryo1.04.04.02.01.06 | Paint Heat Exchangers |  | 11d | 2014-05-05 A | 2014-05-19 A | 5FS+147d | 100% |  | 2014-04-01 | 2014-04-15 | 0d |  |  | FN_MS_EXMP_FY13 [267500%] |  |  | 2,675 |  | 2,675 |  |  | Cryo1.04.04 | A1301.04.04 | A1301.04.04 - Cryo Refrigerator System | 2917 | CR003 |
| 88 | Cryo1.04.04.02.01.07 | Heat Exchanger N2 Vent and Common Header Installation |  | 20d | 2014-07-09 A | 2014-08-05 A | 55 | 100% |  | 2014-07-10 | 2014-08-06 | 20d |  |  | FNAD_CRYO_TECH | 160h | 160h | 4,942.4 | 4,942.4 | 4,942.4 |  |  | Cryo1.04.04 | A1301.04.04 | A1301.04.04 - Cryo Refrigerator System | 2907 | CR002 |
| 89 | Cryo1.04.04.02.02 | Refrig Syst Heat Exchangers Complete | milestone | 0d | 2014-08-05 A | 2014-08-05 A | 84, 88, 87 | 100% |  | 2014-08-06 | 2014-08-06 | 0d |  |  |  |  |  |  |  |  |  |  |  |  |  |  |  |

Notes:
- 72: Text20: Successor?
- 73: Text20: What is the scope of this task? Kind of hard to determine from the name. Successor?
- 78: Text20: What is the scope of this task? Kind of hard to determine from the name.
- 79: Text20: Successor?
- 89: Text20: Successor?

| ID | WBS | Task | Type | Duration | Start | Finish | Predecessors | Complete | Remaining | Baseline start | Baseline finish | Baseline duration | Total slack | Free slack | Constraint | Resources | Work | Actual work | Cost | Baseline cost | Actual cost | BOE File Name | BOE Number | CTC + Name | Cobra WP ID | Cobra WBS # | CTC | CR# | Text20 |
| --- | --- | --- | --- | --- | --- | --- | --- | --- | --- | --- | --- | --- | --- | --- | --- | --- | --- | --- | --- | --- | --- | --- | --- | --- | --- | --- | --- | --- | --- |
| 90 | Cryo1.04.04.03 | **Refrig Syst Expanders** |  | 48d | 2014-07-31 A | 2014-10-07 |  | 67% | 16d | 2014-07-03 | 2014-09-17 | 53d | 57d |  |  |  | 140h | 116h | 10,047.6 | 10,047.6 | 9,017.04 | +Cryo Refrigeration System BOE | Beams 4395 |  |  |  |  |  |  |
| 91 | Cryo1.04.04.03.01 | Refrig Syst Expanders Installation |  | 10d | 2014-07-31 A | 2014-08-13 A | 13FS+100d, 123 | 100% |  | 2014-07-03 | 2014-07-17 | 10d |  |  |  | FNAD_CRYO_TECH; FNAD_CRYO_EN [45%]; FN_MS_STND_FY13 [500000%] | 116h | 116h | 9,017.04 | 9,017.04 | 9,017.04 | +Cryo Refrigeration System BOE | Beams 4395 | A1301.04.04 - Cryo Refrigerator System | 1375 | Cryo1.04.04 | A1301.04.04 | CR002 |  |
| 92 | Cryo1.04.04.03.02 | Refrig Syst Expanders Testing & Validation |  | 5d | 2014-10-01 | 2014-10-07 | 91FS+20d, 21FS+10d, 135FS+28d |  |  | 2014-09-11 | 2014-09-17 | 5d | 57d | 0d |  | FNAD_CRYO_EN [60%] | 24h |  | 1,030.56 | 1,030.56 |  |  |  | A1301.04.04 - Cryo Refrigerator System | 2873 | Cryo1.04.04 | A1301.04.04 |  |  |
| 93 | Cryo1.04.04.03.03 | Refrig Syst Expanders Complete | milestone | 0d | 2014-10-07 | 2014-10-07 | 92 |  |  | 2014-09-17 | 2014-09-17 | 0d | 57d |  |  |  |  |  |  |  |  |  |  |  |  |  |  |  |  |
| 94 | Cryo1.04.04.04 | **Refrig Syst Controls** |  | 325d | 2013-06-17 A | 2014-09-30 A |  | 100% |  | 2013-06-17 | 2014-10-24 | 343d |  |  |  |  | 680h | 680h | 171,299.2 | 171,299.15 | 171,299.2 | +Cryo Refrigeration System BOE | Beams 4395 |  |  |  |  |  |  |
| 95 | Cryo1.04.04.04.01 | **Refrig Syst DCS** |  | 325d | 2013-06-17 A | 2014-09-30 A |  | 100% |  | 2013-06-17 | 2014-10-24 | 343d |  |  |  |  | 680h | 680h | 171,299.2 | 171,299.15 | 171,299.2 | +Cryo Refrigeration System BOE |  |  |  |  |  |  |  |
| 96 | Cryo1.04.04.04.01.01 | Refrig Syst DCS Detailed Engineering |  | 231d | 2013-10-01 A | 2014-09-02 A | 5 | 100% |  | 2013-10-01 | 2014-09-02 | 231d |  |  |  | FNAD_CRYO_EN [32.5%] | 600h | 600h | 25,764 | 30,792 | 25,764 |  |  | A1301.04.04 - Cryo Refrigerator System | 2845 | Cryo1.04.04 | A1301.04.04 |  |  |
| 97 | Cryo1.04.04.04.01.02 | Refrig Syst - First Award for DCS (FY13) |  | 0.12d | 2013-06-17 A | 2013-06-17 A | 7 | 100% |  | 2013-06-17 | 2013-06-17 | 0.12d |  |  |  |  |  |  |  |  |  | +Cryo Refrigeration System BOE | Beams 4395 | A1301.04.04 - Cryo Refrigerator System | 2889 | Cryo1.04.04 | A1301.04.04 |  | Successor? What is this award for? |
| 98 | Cryo1.04.04.04.01.03 | Refrig Syst - 1st DCS Delivery Received |  | 43d | 2013-07-01 A | 2013-08-30 A | 97FS+10d | 100% |  | 2013-07-01 | 2013-08-30 | 43d |  |  |  | FN_MS_STND_FY13 |  |  | 112,100 | 112,100 | 112,100 | +Cryo Refrigeration System BOE | Beams 4395 | A1301.04.04 - Cryo Refrigerator System | 2890 | Cryo1.04.04 | A1301.04.04 |  |  |
| 99 | Cryo1.04.04.04.01.04 | Refrig Syst - Second Award for DCS (FY15) |  | 100d | 2014-01-02 A | 2014-05-22 A | 5 | 100% |  | 2014-01-02 | 2014-05-22 | 100d |  |  | start no earlier than 2014-01-02 |  |  |  |  |  |  | +Cryo Refrigeration System BOE | Beams 4395 | A1301.04.04 - Cryo Refrigerator System | 2891 | Cryo1.04.04 | A1301.04.04 |  | Successor? What is this award for? |
| 100 | Cryo1.04.04.04.01.05 | Refrig Syst - 2nd DCS Delivery Received |  | 140d | 2014-03-07 A | 2014-09-23 A | 99FF+85d | 100% |  | 2014-06-02 | 2014-09-23 | 80d |  |  |  | FN_MS_STND_FY13 |  |  | 30,000 | 30,000 | 30,000 | +Cryo Refrigeration System BOE | Beams 4395 | A1301.04.04 - Cryo Refrigerator System | 2892 | Cryo1.04.04 | A1301.04.04 | CR002 |  |
| 101 | Cryo1.04.04.04.01.06 | Refrig Syst Testing & Validation |  | 5d | 2014-09-24 A | 2014-09-30 A | 96FS+13d, 100, 98 | 100% |  | 2014-09-24 | 2014-10-24 | 23d |  |  |  | FNAD_CRYO_EN [200%] | 80h | 80h | 3,435.2 | 3,435.2 | 3,435.2 |  |  | A1301.04.04 - Cryo Refrigerator System | 2846 | Cryo1.04.04 | A1301.04.04 |  |  |
| 102 | Cryo1.04.04.04.02 | Refrig Syst Controls Complete | milestone | 0d | 2014-09-30 A | 2014-09-30 A | 101 | 100% |  | 2014-10-24 | 2014-10-24 | 0d |  |  |  |  |  |  |  |  |  |  |  |  |  |  |  |  |  |
| 103 | Cryo1.04.04.05 | **Refrig Syst Electrical Infrastructure** |  | 359d | 2013-08-13 A | 2015-01-21 |  | 92% | 29.49d | 2013-08-13 | 2014-12-26 | 344d | 0d |  |  |  | 230h | 230h | 188,671.93 | 188,671.93 | 175,471.94 | +Cryo Refrigeration System BOE | Beams 4395 |  |  | Cryo1.04.04 |  |  |  |
| 104 | Cryo1.04.04.05.01 | Refrig Syst Electrical - Prep Req & Process PO for Electrical T&M |  | 94d | 2013-08-13 A | 2013-12-27 A | 7FS+40d | 100% |  | 2013-08-13 | 2013-12-27 | 94d |  |  |  | FNAD_CRYO_EN [5.3%] | 40h | 40h | 1,838.83 | 2,052.8 | 1,838.84 | +Cryo Refrigeration System BOE | Beams 4395 | A1301.04.04 - Cryo Refrigerator System | 2664 | Cryo1.04.04 | A1301.04.04 |  |  |
| 105 | Cryo1.04.04.05.02 | Refrig Syst Electrical - 1st Award POs for Electrical Work |  | 41d | 2013-10-02 A | 2013-11-27 A | 104SS+35d | 100% |  | 2013-10-02 | 2013-11-27 | 41d |  |  |  |  |  |  |  |  |  | +Cryo Refrigeration System BOE | Beams 4395 | A1301.04.04 - Cryo Refrigerator System | 2665 | Cryo1.04.04 | A1301.04.04 |  |  |
| 106 | Cryo1.04.04.05.03 | Refrig Syst Electrical - 1st Receive Matl for Electrical Work |  | 110d | 2013-10-02 A | 2014-03-13 A | 105SS | 100% |  | 2013-10-02 | 2014-03-13 | 110d |  |  |  | FN_MS_STND_FY13 |  |  | 120,000 | 120,000 | 120,000 |  | Beams 4395 | A1301.04.04 - Cryo Refrigerator System | 2878 | Cryo1.04.04 | A1301.04.04 |  |  |
| 107 | Cryo1.04.04.05.04 | Refrig Syst Electrical - 2nd Award POs for Electrical Work |  | 145d | 2014-05-08 A | 2014-12-03 | 104FS+90d | 90% | 14.5d | 2014-03-27 | 2014-10-20 | 145d | 0d |  |  |  |  |  |  |  |  |  | Beams 4395 | A1301.04.04 - Cryo Refrigerator System | 2877 | Cryo1.04.04 | A1301.04.04 |  |  |
| 108 | Cryo1.04.04.05.05 | Refrig Syst Electrical - 2nd Receive Matl for Electrical Work |  | 160d | 2014-05-30 A | 2015-01-21 | 107FF+30d | 78% | 35.2d | 2014-05-08 | 2014-12-26 | 160d | -12d | 0d |  | FN_MS_STND_FY13 |  |  | 60,000 | 60,000 | 46,800 |  | Beams 4395 | A1301.04.04 - Cryo Refrigerator System | 2879 | Cryo1.04.04 | A1301.04.04 |  |  |
| 109 | Cryo1.04.04.05.06 | Refrig Syst Electrical - Installation (T&M Oversight) Phase 1 |  | 40d | 2014-01-16 A | 2014-03-13 A | 106FF | 100% |  | 2014-01-16 | 2014-03-13 | 40d |  |  |  | FNAD_CRYO_EN [12.5%] | 40h | 40h | 1,717.6 | 2,052.8 | 1,717.6 | +Cryo Refrigeration System BOE | Beams 4395 | A1301.04.04 - Cryo Refrigerator System | 2666 | Cryo1.04.04 | A1301.04.04 |  |  |
| 110 | Cryo1.04.04.05.07 | Refrig Syst Electrical T&M Complete | milestone | 0d | 2014-08-13 A | 2014-08-13 A | 111 | 100% |  | 2014-08-07 | 2014-08-07 | 0d |  |  |  |  |  |  |  |  |  |  |  |  |  |  |  |  | Successor? |
| 111 | Cryo1.04.04.05.08 | Refrig Syst Electrical - Installation (T&M Oversight) Phase 2 |  | 15d | 2014-07-24 A | 2014-08-13 A | 91FF, 109FF | 100% |  | 2014-07-18 | 2014-08-07 | 15d |  |  |  | FNAD_CRYO_EN [33.3%]; FNAD_CRYO_TECH [91.7%] | 150h | 150h | 5,115.5 | 5,115.5 | 5,115.5 |  |  | A1301.04.04 - Cryo Refrigerator System | 2913 | Cryo1.04.04 | A1301.04.04 | CR002 |  |
| 112 | Cryo1.04.04.06 | **Refrig Syst Painting** |  | 60d | 2014-03-07 A | 2014-05-30 A |  | 100% |  | 2014-04-03 | 2014-10-30 | 148d |  |  |  |  | 68h | 68h | 31,900.52 | 31,900.52 | 31,900.52 | +Cryo Refrigeration System BOE | Beams 4395 |  |  |  |  |  |  |
| 113 | Cryo1.04.04.06.01 | Refrig Syst Painting - Prep Req & Process PO |  | 40d | 2014-04-03 A | 2014-05-29 A | 5FS+125d | 100% |  | 2014-04-03 | 2014-07-14 | 71d |  |  |  | FNAD_CRYO_TECH [1.8%] | 4h | 4h | 123.56 | 123.56 | 123.56 | +Cryo Refrigeration System BOE | Beams 4395 | A1301.04.04 - Cryo Refrigerator System | 2733 | Cryo1.04.04 | A1301.04.04 |  |  |
| 114 | Cryo1.04.04.06.02 | Refrig Syst Painting - Award PO |  | 1d | 2014-05-30 A | 2014-05-30 A | 113 | 100% |  | 2014-07-15 | 2014-07-30 | 12d |  |  |  |  |  |  |  |  |  | +Cryo Refrigeration System BOE | Beams 4395 | A1301.04.04 - Cryo Refrigerator System | 2734 | Cryo1.04.04 | A1301.04.04 |  |  |
| 115 | Cryo1.04.04.06.03 | Refrig Syst Painting T&M |  | 60d | 2014-03-07 A | 2014-05-30 A | 114FF | 100% |  | 2014-08-07 | 2014-10-30 | 60d |  |  |  | FNAD_CRYO_TECH [13.3%]; FN_MS_STND_FY13 | 64h | 64h | 31,776.96 | 31,776.96 | 31,776.96 | +Cryo Refrigeration System BOE | Beams 4395 | A1301.04.04 - Cryo Refrigerator System | 2735 | Cryo1.04.04 | A1301.04.04 |  | Successor? |
| 116 | Cryo1.04.04.06.04 | Refrig Syst Painting Complete | milestone | 0d | 2014-05-30 A | 2014-05-30 A | 115 | 100% |  | 2014-10-30 | 2014-10-30 | 0d |  |  |  |  |  |  |  |  |  |  |  |  |  |  |  |  |  |

| ID | WBS | Task | Duration | Start | Finish | Predecessors | Complete | Remaining | Baseline start | Baseline finish | Baseline duration | Total slack | Resources | Work | Actual work | Cost | Baseline cost | Actual cost | BOE File Name | BOE Number | CTC + Name | Cobra WP ID | Cobra WBS # | CTC | CR# |
| --- | --- | --- | --- | --- | --- | --- | --- | --- | --- | --- | --- | --- | --- | --- | --- | --- | --- | --- | --- | --- | --- | --- | --- | --- | --- |
| 117 | Cryo1.04.04.07 | **Refrig Syst Distribution System** | 582d | 2013-10-01 A | 2016-02-01 |  | 76% | 139.07d | 2013-10-01 | 2016-02-01 | 582d | 192d |  | 4736h | 3396h | 497,666.23 | 472,166.23 | 274,868.64 | +Cryo Refrigeration System BOE | Beams 4395 |  |  |  |  |  |
| 118 | Cryo1.04.04.07.01 | **Refrigeration Syst Valve Box** | 213d | 2013-10-01 A | 2014-08-06 A |  | 100% |  | 2013-10-01 | 2014-08-01 | 210d |  |  | 760h | 760h | 49,826 | 49,826 | 49,826 |  |  |  |  |  |  |  |
| 119 | Cryo1.04.04.07.01.01 | Refrigeration Syst Valve Box Procurement | 24d | 2013-10-01 A | 2013-11-01 A | 5 | 100% |  | 2013-10-01 | 2013-11-01 | 24d |  | FNAD_CRYO_TECH [4.2%]; FN_MS_STND_FY13 | 8h | 8h | 15,247.12 | 15,232 | 15,247.12 |  |  | A1301.04.04 - Cryo Refrigerator System | 2848 | Cryo1.04.04 | A1301.04.04 |  |
| 120 | Cryo1.04.04.07.01.02 | Refrigeration Syst g-2 Valve Box Fabrication | 20d | 2014-03-12 A | 2014-04-08 A | 119FS+85d | 100% |  | 2014-03-12 | 2014-04-08 | 20d |  | FNAD_CRYO_TECH; FNAD_CRYO_EN [20%] | 192h | 192h | 6,316.48 | 6,316.48 | 6,316.48 |  |  | A1301.04.04 - Cryo Refrigerator System | 2849 | Cryo1.04.04 | A1301.04.04 | CR002 |
| 121 | Cryo1.04.04.07.01.03 | Refrigeration Syst Mu2e Valve Box Fabrication | 20d | 2014-04-09 A | 2014-05-06 A | 120 | 100% |  | 2014-04-09 | 2014-05-06 | 20d |  | FNAD_CRYO_TECH; FNAD_CRYO_EN [20%] | 192h | 192h | 6,316.48 | 6,316.48 | 6,316.48 |  |  | A1301.04.04 - Cryo Refrigerator System | 2908 | Cryo1.04.04 | A1301.04.04 | CR002 |
| 122 | Cryo1.04.04.07.01.04 | Refrigeration Syst g-2 Valve Box Installation | 27d | 2014-05-15 A | 2014-06-23 A | 120, 146FF+10d | 100% |  | 2014-05-21 | 2014-06-04 | 10d |  | FNAD_CRYO_TECH [74.1%]; FNAD_CRYO_EN [5.6%]; FN_MS_STND_FY13 [500000%] | 172h | 172h | 10,457.68 | 10,457.68 | 10,457.68 |  |  | A1301.04.04 - Cryo Refrigerator System | 2850 | Cryo1.04.04 | A1301.04.04 | CR002 |
| 123 | Cryo1.04.04.07.01.05 | Refrigeration Syst Mu2e Valve Box Installation | 10d | 2014-07-17 A | 2014-07-30 A | 121, 134 | 100% |  | 2014-06-19 | 2014-07-02 | 10d |  | FNAD_CRYO_TECH [200%]; FNAD_CRYO_EN [15%]; FN_MS_STND_FY13 [500000%] | 172h | 172h | 10,457.68 | 10,457.68 | 10,457.68 |  |  | A1301.04.04 - Cryo Refrigerator System | 2909 | Cryo1.04.04 | A1301.04.04 | CR002 |
| 124 | Cryo1.04.04.07.01.06 | Refrigeration Syst Valve Box Checkout | 21d | 2014-07-09 A | 2014-08-06 A | 122, 123FF+5d | 100% |  | 2014-07-03 | 2014-08-01 | 21d |  | FNAD_CRYO_EN [14.3%] | 24h | 24h | 1,030.56 | 1,030.56 | 1,030.56 |  |  | A1301.04.04 - Cryo Refrigerator System | 2851 | Cryo1.04.04 | A1301.04.04 |  |
| 125 | Cryo1.04.04.07.02 | **Refrigeration Syst AP-10 Bayonet Can** | 156d | 2014-01-03 A | 2014-08-13 A |  | 100% |  | 2014-01-03 | 2014-08-15 | 158d |  |  | 416h | 416h | 28,814.24 | 28,814.24 | 28,814.24 |  |  |  |  |  |  |  |
| 126 | Cryo1.04.04.07.02.01 | Refrigeration Syst AP-10 Bayonet Can Procurement | 34d | 2014-01-03 A | 2014-02-20 A | 5FS+62d | 100% |  | 2014-01-03 | 2014-02-20 | 34d |  | FNAD_CRYO_TECH [2.9%]; FN_MS_STND_FY13 [500000%] | 8h | 8h | 5,247.12 | 5,232 | 5,247.12 |  |  | A1301.04.04 - Cryo Refrigerator System | 2853 | Cryo1.04.04 | A1301.04.04 |  |
| 127 | Cryo1.04.04.07.02.02 | Refrigeration Syst AP-10 Bayonet Can Fabrication | 14d | 2014-02-21 A | 2014-03-12 A | 126 | 100% |  | 2014-02-21 | 2014-03-12 | 14d |  | FNAD_CRYO_EN [71.4%] | 80h | 80h | 3,435.2 | 3,435.2 | 3,435.2 |  |  | A1301.04.04 - Cryo Refrigerator System | 2854 | Cryo1.04.04 | A1301.04.04 |  |
| 128 | Cryo1.04.04.07.02.03 | Refrigeration Syst AP-10 Bayonet Can Installation | 10d | 2014-07-17 A | 2014-07-30 A | 127FS+50d, 123FF | 100% |  | 2014-07-03 | 2014-07-17 | 10d |  | FNAD_CRYO_TECH [200%]; FN_MS_STND_FY13 | 160h | 160h | 14,942.4 | 14,942.4 | 14,942.4 |  |  | A1301.04.04 - Cryo Refrigerator System | 2855 | Cryo1.04.04 | A1301.04.04 | CR002 |
| 129 | Cryo1.04.04.07.02.04 | Refrigeration Syst AP-10 Bayonet Can Checkout | 21d | 2014-07-16 A | 2014-08-13 A | 128FF+10d | 100% |  | 2014-07-18 | 2014-08-15 | 21d |  | FNAD_CRYO_TECH | 168h | 168h | 5,189.52 | 5,189.52 | 5,189.52 |  |  | A1301.04.04 - Cryo Refrigerator System | 2856 | Cryo1.04.04 | A1301.04.04 |  |
| 130 | Cryo1.04.04.07.03 | **Refrigeration Syst Transfer Lines** | 223d | 2013-10-01 A | 2014-08-20 A |  | 100% |  | 2013-10-01 | 2014-07-31 | 209d |  |  | 1152h | 1152h | 86,374.47 | 60,874.47 | 86,374.48 |  |  |  |  |  |  |  |
| 131 | Cryo1.04.04.07.03.01 | Refrigeration Syst Transfer Lines Procurement | 42d | 2013-10-01 A | 2013-11-27 A | 5 | 100% |  | 2013-10-01 | 2013-12-02 | 43d |  | FNAD_CRYO_TECH [2.4%]; FN_MS_STND_FY13 | 8h | 8h | 15,247.11 | 15,232 | 15,247.12 |  |  | A1301.04.04 - Cryo Refrigerator System | 2858 | Cryo1.04.04 | A1301.04.04 |  |
| 132 | Cryo1.04.04.07.03.02 | Refrigeration Syst Transfer Lines Fabrication | 60d | 2013-12-02 A | 2014-02-28 A | 131 | 100% |  | 2013-12-03 | 2014-03-03 | 60d |  | FNAD_CRYO_TECH [83.3%] | 400h | 400h | 12,356 | 11,600 | 12,356 |  |  | A1301.04.04 - Cryo Refrigerator System | 2859 | Cryo1.04.04 | A1301.04.04 |  |
| 133 | Cryo1.04.04.07.03.03 | Refrigeration Syst Transfer Lines Installation | 48d | 2014-04-24 A | 2014-07-01 A | 132, 145FS+18d | 100% |  | 2014-04-07 | 2014-05-09 | 25d |  | FNAD_CRYO_TECH [104.2%]; FN_MS_STND_FY13 | 400h | 400h | 47,856 | 22,356 | 47,856 |  |  | A1301.04.04 - Cryo Refrigerator System | 2860 | Cryo1.04.04 | A1301.04.04 | CR002 ,CR004 |
| 134 | Cryo1.04.04.07.03.04 | Refrigeration Syst g-2 Transfer Lines Checkout | 10d | 2014-07-02 A | 2014-07-16 A | 133, 122 | 100% |  | 2014-06-05 | 2014-06-18 | 10d |  | FNAD_CRYO_EN [15%]; FNAD_CRYO_TECH [200%] | 172h | 172h | 5,457.68 | 5,457.68 | 5,457.68 |  |  | A1301.04.04 - Cryo Refrigerator System | 2861 | Cryo1.04.04 | A1301.04.04 | CR002 |
| 135 | Cryo1.04.04.07.03.05 | Refrigeration Syst Mu2e Transfer Lines Checkout | 10d | 2014-08-07 A | 2014-08-20 A | 128FS+5d | 100% |  | 2014-07-18 | 2014-07-31 | 10d |  | FNAD_CRYO_TECH [200%]; FNAD_CRYO_EN [15%] | 172h | 172h | 5,457.68 | 5,457.68 | 5,457.68 |  |  | A1301.04.04 - Cryo Refrigerator System | 2910 | Cryo1.04.04 | A1301.04.04 | CR002 |
| 136 | Cryo1.04.04.07.04 | **Refrigeration Syst g-2/Cradle** | 140d | 2013-10-01 A | 2014-04-23 A |  | 100% |  | 2013-10-01 | 2014-04-28 | 143d |  |  | 404h | 404h | 82,913.36 | 82,913.36 | 82,913.36 |  |  |  |  |  |  |  |
| 137 | Cryo1.04.04.07.04.01 | Refrigeration Syst g-2/Cradle Procurement | 61d | 2013-10-01 A | 2013-12-30 A | 5 | 100% |  | 2013-10-01 | 2014-03-26 | 120d |  | FNAD_CRYO_TECH [1.6%]; FN_MS_STND_FY13 | 8h | 8h | 30,247.12 | 30,232 | 30,247.12 |  |  | A1301.04.04 - Cryo Refrigerator System | 2863 | Cryo1.04.04 | A1301.04.04 |  |
| 138 | Cryo1.04.04.07.04.02 | Refrigeration Syst g-2/Cradle Fabrication | 41d | 2013-10-29 A | 2013-12-30 A | 137SS+20d | 100% |  | 2013-10-29 | 2014-01-29 | 60d |  | FNAD_CRYO_TECH [181.8%]; FNAD_CRYO_EN [13.6%]; FN_MS_STND_FY13 | 344h | 344h | 30,915.36 | 30,511.68 | 30,915.36 |  |  | A1301.04.04 - Cryo Refrigerator System | 2864 | Cryo1.04.04 | A1301.04.04 |  |
| 139 | Cryo1.04.04.07.04.03 | Refrigeration Syst g-2/Cradle Installation/Rigging | 5d | 2014-04-10 A | 2014-04-16 A | 138, 15 | 100% |  | 2014-04-15 | 2014-04-21 | 5d |  | FNAD_CRYO_TECH; FNAD_CRYO_EN [20%]; FN_MS_STND_FY13 | 48h | 48h | 21,579.12 | 21,579.12 | 21,579.12 |  |  | A1301.04.04 - Cryo Refrigerator System | 2865 | Cryo1.04.04 | A1301.04.04 | CR002 |
| 140 | Cryo1.04.04.07.04.04 | Refrigeration Syst g-2/Cradle Checkout | 5d | 2014-04-17 A | 2014-04-23 A | 139 | 100% |  | 2014-04-22 | 2014-04-28 | 5d |  | FNAD_CRYO_EN [10%] | 4h | 4h | 171.76 | 171.76 | 171.76 |  |  | A1301.04.04 - Cryo Refrigerator System | 2866 | Cryo1.04.04 | A1301.04.04 |  |

| ID | WBS | Task | Type | Duration | Start | Finish | Predecessors | Complete | Remaining | Baseline start | Baseline finish | Baseline duration | Total slack | Free slack | Constraint | Resources | Work | Actual work | Cost | Baseline cost | Actual cost | CTC + Name | Cobra WP ID | Cobra WBS # | CTC | CR# | BOE File Name | BOE Number |
| --- | --- | --- | --- | --- | --- | --- | --- | --- | --- | --- | --- | --- | --- | --- | --- | --- | --- | --- | --- | --- | --- | --- | --- | --- | --- | --- | --- | --- |
| 141 | Cryo1.04.04.07.05 | **Refrigeration Syst g-2 Test Box** |  | 148d | 2014-02-03 A | 2014-08-29 A |  | 100% |  | 2014-02-03 | 2014-05-20 | 77d |  |  |  |  | 568h | 568h | 22,818.32 | 22,818.32 | 22,818.32 |  |  |  |  |  |  |  |
| 142 | Cryo1.04.04.07.05.01 | Refrigeration Syst g-2 Test Box Basic Design |  | 20d | 2014-02-03 A | 2014-02-28 A | 5FS+82d | 100% |  | 2014-02-03 | 2014-02-28 | 20d |  |  |  | FNAD_CRYO_EN [25%]; FNAD_MECH_DRAFTER [50%] | 120h | 120h | 4,028 | 4,028 | 4,028 | A1301.04.04 - Cryo Refrigerator System | 2868 | Cryo1.04.04 | A1301.04.04 |  |  |  |
| 143 | Cryo1.04.04.07.05.02 | Refrigeration Syst g-2 Test Box Detail Design |  | 15d | 2014-03-03 A | 2014-03-21 A | 142 | 100% |  | 2014-03-03 | 2014-03-21 | 15d |  |  |  | FNAD_MECH_DRAFTER | 120h | 120h | 3,465.6 | 3,465.6 | 3,465.6 | A1301.04.04 - Cryo Refrigerator System | 2869 | Cryo1.04.04 | A1301.04.04 |  |  |  |
| 144 | Cryo1.04.04.07.05.03 | Refrigeration Syst g-2 Test Box Procurement |  | 10d | 2014-03-10 A | 2014-03-21 A | 143FF | 100% |  | 2014-03-10 | 2014-03-21 | 10d |  |  |  | FNAD_CRYO_TECH; FNAD_CRYO_EN [20%]; FN_MS_STND_FY13 [500000%] | 96h | 96h | 8,158.24 | 8,158.24 | 8,158.24 | A1301.04.04 - Cryo Refrigerator System | 2870 | Cryo1.04.04 | A1301.04.04 | CR002 |  |  |
| 145 | Cryo1.04.04.07.05.04 | Refrigeration Syst g-2 Test Box Fabrication |  | 15d | 2014-03-10 A | 2014-03-28 A | 144FF+5d | 100% |  | 2014-03-17 | 2014-04-04 | 15d |  |  |  | FNAD_CRYO_TECH | 120h | 120h | 3,706.8 | 3,706.8 | 3,706.8 | A1301.04.04 - Cryo Refrigerator System | 2871 | Cryo1.04.04 | A1301.04.04 | CR002 |  |  |
| 146 | Cryo1.04.04.07.05.05 | Refrigeration Syst g-2 Test Box Installation |  | 65d | 2014-05-30 A | 2014-08-29 A | 145, 133 | 100% |  | 2014-05-12 | 2014-05-20 | 7d |  |  |  | FNAD_CRYO_TECH [21.5%] | 112h | 112h | 3,459.68 | 3,459.68 | 3,459.68 | A1301.04.04 - Cryo Refrigerator System | 2872 | Cryo1.04.04 | A1301.04.04 | CR002 |  |  |
| 147 | Cryo1.04.04.07.06 | Refrigeration Syst Safety Documents |  | 64d | 2014-06-03 A | 2014-09-02 A | 5FS+167d | 100% |  | 2014-06-03 | 2014-09-02 | 64d |  |  |  | FNAD_CRYO_EN [18.8%] | 96h | 96h | 4,122.24 | 4,122.24 | 4,122.24 | A1301.04.04 - Cryo Refrigerator System | 2875 | Cryo1.04.04 | A1301.04.04 |  |  |  |
| 148 | Cryo1.04.04.07.07 | Design Mu2e Transfer Line Bayonet Can |  | 128d | 2014-10-01 | 2015-04-07 | 6 |  |  | 2014-10-01 | 2015-04-07 | 128d | 192d | 0d |  | FNAD_MECH_DRAFTER [48.8%] | 500h |  | 14,440 | 14,440 |  | A1301.04.04 - Cryo Refrigerator System | 2825 | Cryo1.04.04 | A1301.04.04 |  | +Cryo Refrigeration System BOE | Beams 4395 |
| 149 | Cryo1.04.04.07.08 | Dwgs Ready for Mu2e Transfer Line Bayonet Can | milestone | 0d | 2015-04-07 | 2015-04-07 | 148 |  |  | 2015-04-07 | 2015-04-07 | 0d | 192d | 0d |  |  |  |  |  |  |  |  |  |  |  |  |  |  |
| 150 | Cryo1.04.04.07.09 | Prep Req & Process PO for Mu2e Transfer Line Bayonet Can |  | 41d | 2015-04-08 | 2015-06-04 | 149 |  |  | 2015-04-08 | 2015-06-04 | 41d | 192d | 0d |  | FNAD_CRYO_EN [12.2%] | 40h |  | 1,717.6 | 1,717.6 |  | A1301.04.04 - Cryo Refrigerator System | 2827 | Cryo1.04.04 | A1301.04.04 |  | +Cryo Refrigeration System BOE | Beams 4395 |
| 151 | Cryo1.04.04.07.10 | Award PO for Mu2e Transfer Line Bayonet Can |  | 1d | 2015-06-05 | 2015-06-05 | 5FS+240d, 150 |  |  | 2015-06-05 | 2015-06-05 | 1d | 192d | 0d |  |  |  |  |  |  |  | A1301.04.04 - Cryo Refrigerator System | 2828 | Cryo1.04.04 | A1301.04.04 |  | +Cryo Refrigeration System BOE | Beams 4395 |
| 152 | Cryo1.04.04.07.11 | Procured Items Delivered for Mu2e Transfer Line Bayonet Can |  | 1d | 2015-11-30 | 2015-11-30 | 151FS+120d |  |  | 2015-11-30 | 2015-11-30 | 1d | 192d | 0d |  | FN_MS_STND_FY13 |  |  | 180,000 | 180,000 |  | A1301.04.04 - Cryo Refrigerator System | 2829 | Cryo1.04.04 | A1301.04.04 |  | +Cryo Refrigeration System BOE | Beams 4395 |
| 153 | Cryo1.04.04.07.12 | Bayonet Cans Installed for Mu2e Transfer Line Bayonet Can |  | 40d | 2015-12-01 | 2016-02-01 | 152 |  |  | 2015-12-01 | 2016-02-01 | 40d | 192d | 170d |  | FNAD_CRYO_TECH [200%]; FNAD_CRYO_EN [50%] | 800h |  | 26,640 | 26,640 |  | A1301.04.04 - Cryo Refrigerator System | 2830 | Cryo1.04.04 | A1301.04.04 |  | +Cryo Refrigeration System BOE | Beams 4395 |
| 154 | Cryo1.04.04.08 | **Strainer** |  | 71d | 2014-08-21 A | 2014-12-02 |  | 52% | 33.81d | 2014-08-07 | 2014-11-14 | 0d | 640d |  |  |  |  |  | 43,423 |  |  |  |  |  |  |  |  |  |
| 155 | Cryo1.04.04.08.01 | Prep Req & Process PO for Strainer |  | 10d | 2014-08-21 A | 2014-09-04 A | 5FS+223d | 100% |  | 2014-08-07 | 2014-08-20 | 10d |  |  |  |  |  |  |  |  |  | A1301.04.04 - Cryo Refrigerator System | 2926 | Cryo1.04.04 | A1301.04.04 | CR007 |  |  |
| 156 | Cryo1.04.04.08.02 | Award PO for Strainer |  | 1d | 2014-09-05 A | 2014-09-05 A | 155 | 100% |  | 2014-08-21 | 2014-08-21 | 1d |  |  |  |  |  |  |  |  |  | A1301.04.04 - Cryo Refrigerator System | 2927 | Cryo1.04.04 | A1301.04.04 | CR007 |  |  |
| 157 | Cryo1.04.04.08.03 | Deliver & Install Strainer |  | 10d | 2014-11-17 | 2014-12-02 | 156FS+50d |  |  | 2014-11-03 | 2014-11-14 | 10d | 640d |  |  |  |  |  | 43,423 | 44,248 |  | A1301.04.04 - Cryo Refrigerator System | 2928 | Cryo1.04.04 | A1301.04.04 | CR007 |  |  |
| 158 | Cryo1.04.04.09 | Cryo Refrigeration System Complete | milestone | 0d | 2015-01-21 | 2015-01-21 | 108, 140, 147, 124, 129, 205 |  |  | 2014-12-26 | 2014-12-26 | 0d | -12d | 0d |  |  |  |  |  |  |  |  |  |  |  |  |  |  |
| 159 | Cryo1.04.05 | **Cryo Compressor System** |  | 261d | 2013-06-17 A | 2014-06-30 A |  | 100% |  | 2013-06-17 | 2014-09-23 | 320d |  |  |  |  | 1288h | 1288h | 283,452 | 283,452 | 283,452 |  |  | Cryo1.04.05 | A1301.04.05 |  | +Cryo Compressor System BOE | Beams 4395 |
| 160 | Cryo1.04.05.01 | **Compressor System - T&M Work** |  | 248d | 2013-07-03 A | 2014-06-27 A |  | 100% |  | 2013-07-03 | 2014-09-02 | 293d |  |  |  |  | 120h | 120h | 31,067.6 | 31,067.6 | 31,067.6 |  |  |  |  |  | +Cryo Compressor System BOE | Beams 4395 |
| 161 | Cryo1.04.05.01.01 | Compressor Syst T&M - Award PO for Rigging T&M Work |  | 0.12d | 2013-07-03 A | 2013-07-03 A | 7FS+12d | 100% |  | 2013-07-03 | 2013-07-03 | 0.12d |  |  |  |  |  |  |  |  |  | A1301.04.05 - Cryo Compressor System | 2680 | Cryo1.04.05 | A1301.04.05 |  | +Cryo Compressor System BOE | Beams 4395 |
| 162 | Cryo1.04.05.01.02 | Compressor Syst - Rigging T&M |  | 2d | 2013-07-29 A | 2013-07-30 A | 161 | 100% |  | 2013-07-29 | 2013-07-30 | 2d |  |  | start no earlier than 2013-07-29 | FNAD_CRYO_TECH [62.5%]; FN_MS_STND_FY13 [569000%] | 10h | 10h | 5,979.7 | 5,980 | 5,979.7 | A1301.04.05 - Cryo Compressor System | 2794 | Cryo1.04.05 | A1301.04.05 |  |  |  |
| 163 | Cryo1.04.05.01.03 | Compressor Syst T&M - Award PO for Electrical T&M Work |  | 1d | 2014-02-27 A | 2014-02-27 A | 5FS+100d | 100% |  | 2014-02-27 | 2014-02-27 | 1d |  |  |  |  |  |  |  |  |  | A1301.04.05 - Cryo Compressor System | 2806 | Cryo1.04.05 | A1301.04.05 |  | +Cryo Compressor System BOE | Beams 4395 |
| 164 | Cryo1.04.05.01.04 | Compressor Syst - T&M |  | 65d | 2014-03-28 A | 2014-06-27 A | 163FS+20d | 100% |  | 2014-02-28 | 2014-09-02 | 130d |  |  |  | FNAD_CRYO_TECH [21.2%]; FN_MS_STND_FY13 | 110h | 110h | 25,087.9 | 25,087.9 | 25,087.9 | A1301.04.05 - Cryo Compressor System | 1161 | Cryo1.04.05 | A1301.04.05 |  | +Cryo Compressor System BOE | Beams 4395 |
| 165 | Cryo1.04.05.01.05 | Compressor System - T&M Work Complete | milestone | 0d | 2014-06-27 A | 2014-06-27 A | 164, 162 | 100% |  | 2014-09-02 | 2014-09-02 | 0d |  |  |  |  |  |  |  |  |  |  |  | Cryo1.04.05 |  |  |  |  |

| ID | WBS | Task | Type | Duration | Start | Finish | Predecessors | Complete | Baseline start | Baseline finish | Baseline duration | Constraint | Resources | Work | Actual work | Cost | Baseline cost | Actual cost | BOE File Name | BOE Number | Text20 | CTC + Name | Cobra WP ID | Cobra WBS # | CTC | CR# |
| --- | --- | --- | --- | --- | --- | --- | --- | --- | --- | --- | --- | --- | --- | --- | --- | --- | --- | --- | --- | --- | --- | --- | --- | --- | --- | --- |
| 166 | Cryo1.04.05.02 | **Water System Valves & Refurbishment** |  | 62.12d | 2013-06-17 A | 2013-09-13 A |  | 100% | 2013-06-17 | 2013-09-13 | 62.12d |  |  | 8h | 8h | 40,231.76 | 40,231.76 | 40,231.76 | +Cryo Compressor System BOE | Beams 4395 | Need to detail the procurement. |  |  |  |  |  |
| 167 | Cryo1.04.05.02.01 | Prep Req & Process PO for Water System Valves |  | 42d | 2013-06-17 A | 2013-08-14 A | 7 | 100% | 2013-06-17 | 2013-08-14 | 42d |  | FNAD_CRYO_TECH [2.4%] | 8h | 8h | 231.76 | 232 | 231.76 | +Cryo Compressor System BOE | Beams 4395 |  | A1301.04.05 - Cryo Compressor System | 2590 | Cryo1.04.05 | A1301.04.05 |  |
| 168 | Cryo1.04.05.02.02 | Water System Valves Award |  | 0.12d | 2013-08-15 A | 2013-08-15 A | 167 | 100% | 2013-08-15 | 2013-08-15 | 0.12d |  |  |  |  |  |  |  | +Cryo Compressor System BOE | Beams 4395 |  | A1301.04.05 - Cryo Compressor System | 2591 | Cryo1.04.05 | A1301.04.05 |  |
| 169 | Cryo1.04.05.02.03 | Water System Valves Delivery |  | 15d | 2013-08-22 A | 2013-09-13 A | 168FS+5d | 100% | 2013-08-22 | 2013-09-13 | 15d |  | FN_MS_STND_FY13 |  |  | 17,000 | 17,000 | 17,000 | +Cryo Compressor System BOE | Beams 4395 |  | A1301.04.05 - Cryo Compressor System | 2592 | Cryo1.04.05 | A1301.04.05 |  |
| 170 | Cryo1.04.05.02.04 | Account Payback for items purchased before Project Plan approved |  | 1d | 2013-07-01 A | 2013-07-01 A |  | 100% | 2013-07-01 | 2013-07-29 | 20d | start no earlier than 2013-07-01 | FN_MS_STND_FY13 |  |  | 23,000 | 23,000 | 23,000 |  |  |  | A1301.04.05 - Cryo Compressor System | 2898 | Cryo1.04.05 | A1301.04.05 |  |
| 171 | Cryo1.04.05.03 | Compressor Syst Paint vessels & base |  | 20d | 2014-05-01 A | 2014-05-29 A | 5FS+145d | 100% | 2014-02-27 | 2014-09-23 | 146d |  | FNAD_CRYO_TECH [50%]; FN_MS_STND_FY13 | 80h | 80h | 42,471.2 | 42,471.2 | 42,471.2 | +Cryo Compressor System BOE | Beams 4395 | Successor? | A1301.04.05 - Cryo Compressor System | 858 | Cryo1.04.05 | A1301.04.05 |  |
| 172 | Cryo1.04.05.04 | Compressor Syst Electrical |  | 140d | 2013-10-09 A | 2014-05-01 A | 7FS+80d | 100% | 2013-10-09 | 2014-05-01 | 140d | start no earlier than 2013-02-01 | FNAD_CRYO_TECH [7.1%] | 80h | 80h | 2,471.2 | 2,320 | 2,471.2 | +Cryo Compressor System BOE | Beams 4395 | Need predecessor | A1301.04.05 - Cryo Compressor System | 855 | Cryo1.04.05 | A1301.04.05 |  |
| 173 | Cryo1.04.05.05 | Compressor Syst Electrical Complete | milestone | 0d | 2014-05-01 A | 2014-05-01 A | 172, 211 | 100% | 2014-05-01 | 2014-05-01 | 0d |  |  |  |  |  |  |  |  |  |  |  |  |  |  |  |
| 174 | Cryo1.04.05.06 | Compressor Syst Controls |  | 181d | 2013-10-09 A | 2014-06-30 A | 7FS+80d | 100% | 2013-10-09 | 2014-05-01 | 140d |  | FNAD_CRYO_TECH [27.6%] | 400h | 400h | 12,356 | 11,600 | 12,356 | +Cryo Compressor System BOE | Beams 4395 | Successor? | A1301.04.05 - Cryo Compressor System | 856 | Cryo1.04.05 | A1301.04.05 |  |
| 175 | Cryo1.04.05.07 | Compressor Syst Controls Complete | milestone | 0d | 2014-06-30 A | 2014-06-30 A | 174 | 100% | 2014-05-01 | 2014-05-01 | 0d |  |  |  |  |  |  |  |  |  |  |  |  |  |  |  |
| 176 | Cryo1.04.05.08 | **Cryo Compressor System Heat Exchangers** |  | 202d | 2013-08-09 A | 2014-05-30 A |  | 100% | 2013-08-09 | 2014-06-19 | 216d |  |  | 600h | 600h | 154,854.24 | 154,854.24 | 154,854.24 |  |  |  |  |  |  |  |  |
| 177 | Cryo1.04.05.08.01 | Prep Paperwork & Obtain Approval for Sole Source for Heat Exchangers (5) |  | 20d | 2013-08-09 A | 2013-09-06 A | 7FS+38d | 100% | 2013-08-09 | 2013-09-06 | 20d |  | FNAD_CRYO_EN [5%] | 8h | 8h | 410.56 | 410.56 | 410.56 |  |  |  | A1301.04.05 - Cryo Compressor System | 2810 | Cryo1.04.05 | A1301.04.05 |  |
| 178 | Cryo1.04.05.08.02 | Release Order for Heat Exchangers (5) |  | 0.12d | 2013-09-09 A | 2013-09-09 A | 177 | 100% | 2013-09-09 | 2013-09-09 | 0.12d |  |  |  |  |  |  |  | +Cryo Compressor System BOE | Beams 4395 |  | A1301.04.05 - Cryo Compressor System | 2811 | Cryo1.04.05 | A1301.04.05 |  |
| 179 | Cryo1.04.05.08.03 | Dwgs to Fermi for Approval for Heat Exchangers (5) | milestone | 0d | 2013-10-10 A | 2013-10-10 A | 178FS+23d | 100% | 2013-10-10 | 2013-10-10 | 0d |  |  |  |  |  |  |  |  |  |  |  |  |  |  |  |
| 180 | Cryo1.04.05.08.04 | Approval of Dwgs by Fermi for Heat Exchangers (5) |  | 10d | 2013-10-11 A | 2013-10-24 A | 179 | 100% | 2013-10-11 | 2013-10-24 | 10d |  | FNAD_CRYO_EN | 80h | 80h | 3,435.2 | 4,105.6 | 3,435.2 |  |  |  | A1301.04.05 - Cryo Compressor System | 2814 | Cryo1.04.05 | A1301.04.05 |  |
| 181 | Cryo1.04.05.08.05 | Receive & Examine Heat Exchangers (5) |  | 1d | 2014-01-16 A | 2014-01-16 A | 180FS+53d | 100% | 2014-02-06 | 2014-02-06 | 1d |  | FNAD_CRYO_EN [200%]; FNAD_CRYO_TECH [400%]; FN_MS_STND_FY13 | 48h | 48h | 136,675.52 | 136,749.12 | 136,675.52 |  |  |  | A1301.04.05 - Cryo Compressor System | 2812 | Cryo1.04.05 | A1301.04.05 |  |
| 182 | Cryo1.04.05.08.06 | Move Heat Exchanders to A0 |  | 10d | 2014-01-17 A | 2014-01-31 A | 181 | 100% | 2014-02-07 | 2014-02-07 | 1d |  | FNAD_CRYO_TECH [20%] | 16h | 16h | 494.24 | 464 | 494.24 |  |  |  | A1301.04.05 - Cryo Compressor System | 2793 | Cryo1.04.05 | A1301.04.05 |  |
| 183 | Cryo1.04.05.08.07 | Replace A0 Heat Exchangers |  | 24d | 2014-04-28 A | 2014-05-30 A | 182FS+60d | 100% | 2014-04-28 | 2014-06-05 | 28d |  | FNAD_CRYO_TECH [233.3%] | 448h | 448h | 13,838.72 | 13,838.72 | 13,838.72 |  |  |  | A1301.04.05 - Cryo Compressor System | 2815 | Cryo1.04.05 | A1301.04.05 |  |
| 184 | Cryo1.04.05.08.08 | Complete Heat Exchangers Installation | milestone | 0d | 2014-05-30 A | 2014-05-30 A | 183 | 100% | 2014-06-19 | 2014-06-19 | 0d |  |  |  |  |  |  |  |  |  |  |  |  |  |  |  |
| 185 | Cryo1.04.06 | **Cryo Interconnect Piping** |  | 211d | 2013-07-26 A | 2014-05-29 A |  | 100% | 2013-07-26 | 2014-07-30 | 254d |  |  | 2542h | 2542h | 459,834.93 | 516,424.18 | 459,834.93 | +Cryo Interconnect Piping BOE | Beams 4395 |  |  |  | Cryo1.04.06 | A1301.04.06 |  |
| 186 | Cryo1.04.06.01 | Interconnect Piping Prep Purch Req & Process PO for all work |  | 20d | 2013-07-26 A | 2013-08-22 A | 7FS+28d | 100% | 2013-07-26 | 2013-08-22 | 20d |  | FNAD_CRYO_EN [78.8%] | 126h | 126h | 6,466.32 | 6,466.32 | 6,466.32 | +Cryo Interconnect Piping BOE | Beams 4395 |  | A1301.04.06 - Cryo Interconnect Piping | 2687 | Cryo1.04.06 | A1301.04.06 |  |
| 187 | Cryo1.04.06.02 | Interconnect Piping Award A0 to MC-1 Suction & Discharge Pipe |  | 1d | 2013-08-23 A | 2013-08-23 A | 186 | 100% | 2013-08-23 | 2013-08-23 | 1d |  |  |  |  |  |  |  | +Cryo Interconnect Piping BOE | Beams 4395 |  | A1301.04.06 - Cryo Interconnect Piping | 2690 | Cryo1.04.06 | A1301.04.06 |  |
| 188 | Cryo1.04.06.03 | Interconnect Piping Deliver & Install A0 to MC-1 Suction & Discharge Pipe |  | 10d | 2013-09-17 A | 2013-09-30 A | 187FS+15d | 100% | 2013-09-17 | 2013-09-30 | 10d |  | FN_MS_STND_FY13 |  |  | 76,678 | 76,678 | 76,678 | +Cryo Interconnect Piping BOE | Beams 4395 |  | A1301.04.06 - Cryo Interconnect Piping | 2691 | Cryo1.04.06 | A1301.04.06 |  |
| 189 | Cryo1.04.06.04 | Interconnect Piping Award Misc FY13 |  | 0.12d | 2013-08-23 A | 2013-08-23 A | 186 | 100% | 2013-08-23 | 2013-08-23 | 0.12d |  |  |  |  |  |  |  | +Cryo Interconnect Piping BOE | Beams 4395 |  | A1301.04.06 - Cryo Interconnect Piping | 2886 | Cryo1.04.06 | A1301.04.06 |  |
| 190 | Cryo1.04.06.05 | Interconnect Piping Award Misc FY14 |  | 0.12d | 2013-10-01 A | 2013-10-01 A | 5 | 100% | 2013-10-01 | 2013-10-01 | 0.12d |  |  |  |  |  |  |  | +Cryo Interconnect Piping BOE | Beams 4395 |  | A1301.04.06 - Cryo Interconnect Piping | 2897 | Cryo1.04.06 | A1301.04.06 |  |
| 191 | Cryo1.04.06.06 | Interconnect Piping Deliver Misc |  | 50d | 2013-08-23 A | 2013-11-04 A | 189, 190FF+20d | 100% | 2013-08-23 | 2013-11-04 | 50d |  | FN_MS_STND_FY13 |  |  | 110,000 | 110,000 | 110,000 | +Cryo Interconnect Piping BOE | Beams 4395 |  | A1301.04.06 - Cryo Interconnect Piping | 2887 | Cryo1.04.06 | A1301.04.06 |  |
| 192 | Cryo1.04.06.07 | Interconnect Piping Award Tank Farm Headers |  | 0.12d | 2013-10-01 A | 2013-10-01 A | 186, 5 | 100% | 2013-10-01 | 2013-10-01 | 0.12d |  |  |  |  |  |  |  | +Cryo Interconnect Piping BOE | Beams 4395 |  | A1301.04.06 - Cryo Interconnect Piping | 2768 | Cryo1.04.06 | A1301.04.06 |  |
| 193 | Cryo1.04.06.08 | Interconnect Piping Deliver & Install Farm Headers |  | 50d | 2013-10-22 A | 2014-01-08 A | 192FS+15d | 100% | 2013-10-22 | 2014-01-08 | 50d |  | FN_MS_STND_FY13 |  |  | 29,872 | 29,872 | 29,872 | +Cryo Interconnect Piping BOE | Beams 4395 |  | A1301.04.06 - Cryo Interconnect Piping | 2767 | Cryo1.04.06 | A1301.04.06 |  |
| 194 | Cryo1.04.06.09 | Interconnect Piping Award PO for Parts for MC-1 Bldg Header |  | 23d | 2013-10-07 A | 2013-11-06 A | 186FS+30d | 100% | 2013-10-07 | 2013-11-06 | 23d |  |  |  |  |  |  |  | +Cryo Interconnect Piping BOE | Beams 4395 |  | A1301.04.06 - Cryo Interconnect Piping | 2883 | Cryo1.04.06 | A1301.04.06 |  |
| 195 | Cryo1.04.06.10 | Interconnect Piping Deliver Parts for MC-1 Bldg Header |  | 38d | 2013-10-07 A | 2013-11-27 A | 194SS | 100% | 2013-10-07 | 2013-11-27 | 38d | finish no earlier than 2013-11-27 | FN_MS_STND_FY13 |  |  | 15,000 | 15,000 | 15,000 | +Cryo Interconnect Piping BOE | Beams 4395 |  | A1301.04.06 - Cryo Interconnect Piping | 2884 | Cryo1.04.06 | A1301.04.06 |  |
| 196 | Cryo1.04.06.11 | OS of Interconnect piping - A0 to MC-1 Discharge & Suction Header |  | 165d | 2013-08-01 A | 2014-03-31 A | 7FS+32d, 195FF | 100% | 2013-08-01 | 2014-07-30 | 250d |  | FNAD_CRYO_TECH [118.2%]; FNAD_CRYO_EN [46.7%] | 2176h | 2176h | 75,191.01 | 76,853.12 | 75,191.01 | +Cryo Interconnect Piping BOE | Beams 4395 | Is there a procurement cycle? Need predecessor | A1301.04.06 - Cryo Interconnect Piping | 2692 | Cryo1.04.06 | A1301.04.06 |  |
| 197 | Cryo1.04.06.12 | Account Payback for items purchased before Project Plan approved |  | 1d | 2013-08-01 A | 2013-08-01 A |  | 100% | 2013-08-01 | 2013-08-30 | 22d | start no earlier than 2013-08-01 | FN_MS_STND_FY13 |  |  | 16,114 | 16,114 | 16,114 | +Cryo Interconnect Piping BOE | Beams 4395 |  | A1301.04.06 - Cryo Interconnect Piping | 2888 | Cryo1.04.06 | A1301.04.06 |  |
| 198 | Cryo1.04.06.13 | Interconnect Piping Underground Connection to MC-1 |  | 24d | 2013-10-01 A | 2013-11-01 A | 5 | 100% | 2013-10-01 | 2013-11-01 | 24d | start no earlier than 2013-09-09 | FNAD_CRYO_TECH [20.8%]; FN_MS_STND_FY13 | 40h | 40h | 31,235.6 | 31,160 | 31,235.6 | +Cryo Interconnect Piping BOE | Beams 4395 |  | A1301.04.06 - Cryo Interconnect Piping | 2822 | Cryo1.04.06 | A1301.04.06 |  |
| 199 | Cryo1.04.06.14 | Install Experimental Hall Pipes on Stands |  | 5d | 2014-04-10 A | 2014-04-16 A | 15 | 100% | 2014-04-15 | 2014-04-21 | 5d |  | FNAD_CRYO_TECH | 40h | 40h | 1,235.6 | 1,235.6 | 1,235.6 |  |  |  | A1301.04.06 - Cryo Interconnect Piping | 2916 | Cryo1.04.06 | A1301.04.06 | CR002 |
| 200 | Cryo1.04.06.15 | Interconnect Piping Award MC-1 Refrig Bldg Headers |  | 10d | 2014-03-10 A | 2014-03-21 A | 186FS+133d | 100% | 2014-03-10 | 2014-03-21 | 10d |  |  |  |  |  |  |  | +Cryo Interconnect Piping BOE | Beams 4395 |  | A1301.04.06 - Cryo Interconnect Piping | 2766 | Cryo1.04.06 | A1301.04.06 |  |
| 201 | Cryo1.04.06.16 | Interconnect Piping Contractor Install MC-1 Refrig Bldg Headers |  | 25d | 2014-03-24 A | 2014-04-25 A | 200, 13, 198, 14 | 100% | 2014-03-24 | 2014-04-25 | 25d |  | FN_MS_STND_FY13 |  |  | 48,300 | 48,300 | 48,300 | +Cryo Interconnect Piping BOE | Beams 4395 |  | A1301.04.06 - Cryo Interconnect Piping | 2765 | Cryo1.04.06 | A1301.04.06 | CR002 |
| 202 | Cryo1.04.06.17 | Interconnect Piping Award MC-1 Exp Hall Headers |  | 1d | 2014-04-23 A | 2014-04-23 A | 186FS+165d | 100% | 2014-04-23 | 2014-04-23 | 1d |  |  |  |  |  |  |  |  |  |  | A1301.04.06 - Cryo Interconnect Piping | 2911 | Cryo1.04.06 | A1301.04.06 | CR004 |
| 203 | Cryo1.04.06.18 | Interconnect Piping Contractor Install MC-1 Exp Hall Headers |  | 25d | 2014-04-24 A | 2014-05-29 A | 202, 199 | 100% | 2014-05-08 | 2014-06-12 | 25d |  | FN_MS_STND_FY13 |  |  | 36,400 | 101,573 | 36,400 |  |  |  | A1301.04.06 - Cryo Interconnect Piping | 2912 | Cryo1.04.06 | A1301.04.06 | CR002, CR004 |
| 204 | Cryo1.04.06.19 | Additional connection to the nitrogen header in support of g-2 |  | 20d | 2014-05-01 A | 2014-05-29 A | 203FF | 100% | 2014-05-01 | 2014-05-29 | 0d |  |  |  |  | 8,400 |  | 8,400 |  |  |  | A1301.04.06 - Cryo Interconnect Piping | 2918 | Cryo1.04.06 | A1301.04.06 | CR005 |
| 205 | Cryo1.04.06.20 | Refrig Syst Interconnect Piping - Installation Complete | milestone | 0d | 2014-05-29 A | 2014-05-29 A | 188, 193, 196, 66, 191, 206, 207 | 100% | 2014-07-30 | 2014-07-30 | 0d |  |  |  |  |  |  |  |  |  |  |  |  |  |  |  |
| 206 | Cryo1.04.06.21 | Interconnect Piping Installation Oversight MC-1 Refrig Bldg Headers |  | 25d | 2014-03-24 A | 2014-04-25 A | 201FF | 100% | 2014-02-10 | 2014-04-25 | 55d |  | FNAD_CRYO_TECH [55%] | 110h | 110h | 3,397.9 | 3,397.9 | 3,397.9 |  |  |  | A1301.04.06 - Cryo Interconnect Piping | 2914 | Cryo1.04.06 | A1301.04.06 | CR002 |
| 207 | Cryo1.04.06.22 | Interconnect Piping Installation Oversight MC-1 Exp Hall Headers |  | 25d | 2014-04-24 A | 2014-05-29 A | 203FF | 100% | 2014-05-08 | 2014-06-12 | 25d |  | FNAD_CRYO_TECH [25%] | 50h | 50h | 1,544.5 | 1,544.5 | 1,544.5 |  |  |  | A1301.04.06 - Cryo Interconnect Piping | 2915 | Cryo1.04.06 | A1301.04.06 | CR002 |

Notes:
- 196: Includes 300 hours of pipefitter @$90/hour = $27000

| ID | WBS | Task | Type | Duration | Start | Finish | Predecessors | Complete | Remaining | Baseline start | Baseline finish | Baseline duration | Total slack | Free slack | Constraint | Resources | Work | Actual work | Cost | Baseline cost | Actual cost | BOE File Name | BOE Number | Cobra WBS # | Text20 | CTC | CTC + Name | Cobra WP ID | Misc |
| --- | --- | --- | --- | --- | --- | --- | --- | --- | --- | --- | --- | --- | --- | --- | --- | --- | --- | --- | --- | --- | --- | --- | --- | --- | --- | --- | --- | --- | --- |
| 208 | Cryo1.04.07 | **Cryo Interconnect Electrical & Controls** |  | 282d | 2013-06-17 A | 2014-07-30 A |  | 100% |  | 2013-06-17 | 2014-05-23 | 236d |  |  |  |  | 880h | 880h | 91,553.2 | 91,553.15 | 91,553.2 | +Cryo Interconnect Elect & Controls BOE | Beams 4395 | Cryo1.04.07 | Successor? | A1301.04.07 |  |  |  |
| 209 | Cryo1.04.07.01 | Procure Compressor System Controls |  | 1d | 2013-06-17 A | 2013-06-17 A | 7 | 100% |  | 2013-06-17 | 2013-07-15 | 20d |  |  |  | FN_MS_STND_FY13 |  |  | 37,700 | 37,700 | 37,700 |  |  | Cryo1.04.07 |  | A1301.04.07 | A1301.04.07 - Cryo Interconnect Electrical & Controls | 2893 |  |
| 210 | Cryo1.04.07.02 | Procure Xgallery Fiber Connection |  | 24d | 2013-11-19 A | 2013-12-26 A | 5FS+35d | 100% |  | 2013-11-19 | 2013-12-26 | 24d |  |  |  | FNAD_CRYO_TECH [8.3%]; FN_MS_STND_FY13 | 16h | 16h | 17,164.24 | 17,134 | 17,164.24 | +Cryo Interconnect Elect & Controls BOE | Beams 4395 | Cryo1.04.07 |  | A1301.04.07 | A1301.04.07 - Cryo Interconnect Electrical & Controls | 2695 |  |
| 211 | Cryo1.04.07.03 | Run Fiber Cable between A0 & MC-1 |  | 43d | 2013-12-27 A | 2014-02-28 A | 210, 209 | 100% |  | 2013-12-27 | 2014-03-10 | 49d |  |  |  | FNAD_CRYO_TECH [18.6%]; FN_MS_STND_FY13 | 64h | 64h | 11,976.96 | 11,856 | 11,976.96 | +Cryo Interconnect Elect & Controls BOE | Beams 4395 | Cryo1.04.07 |  | A1301.04.07 | A1301.04.07 - Cryo Interconnect Electrical & Controls | 2696 |  |
| 212 | Cryo1.04.07.04 | Interconnect Electrical & Controls Engineering |  | 208d | 2013-10-01 A | 2014-07-30 A | 5 | 100% |  | 2013-10-01 | 2014-05-23 | 162d |  |  |  | FNAD_CRYO_TECH [48.1%] | 800h | 800h | 24,712 | 23,200 | 24,712 | +Cryo Interconnect Elect & Controls BOE | Beams 4395 | Cryo1.04.07 |  | A1301.04.07 | A1301.04.07 - Cryo Interconnect Electrical & Controls | 2697 |  |
| 213 | Cryo1.05 | **Cryo Experiment interfaces** |  | 902d | 2013-08-19 A | 2017-03-27 |  | 9% | 819.37d | 2013-08-19 | 2017-03-27 | 902d | 22d |  |  |  | 8410h | 454.8h | 876,227.4 | 876,227.4 | 20,953.71 |  |  | Cryo1.05 |  |  |  |  |  |
| 214 | Cryo1.05.01 | **Mu2e Interface Connection** |  | 712d | 2014-05-22 A | 2017-03-27 |  | 6% | 667.15d | 2014-05-22 | 2017-03-27 | 712d | 22d |  |  |  | 8240h | 284.8h | 867,503 | 867,503 | 12,229.31 | +Cryo Mu2e Interface Connection BOE | Beams 4395 | Cryo1.05.01 |  | A1301.05.01 |  |  |  |
| 215 | Cryo1.05.01.01 | Mu2e Interface - Basic Engineering |  | 40d | 2014-05-22 A | 2014-07-18 A | 5FS+160d | 100% |  | 2014-05-22 | 2014-07-18 | 40d |  |  |  | FNAD_CRYO_EN [75%] | 240h | 240h | 10,305.6 | 10,305.6 | 10,305.6 | +Cryo Mu2e Interface Connection BOE | Beams 4395 | Cryo1.05.01 |  | A1301.05.01 | A1301.05.01 - Mu2e Interface Connection | 2698 |  |
| 216 | Cryo1.05.01.02 | Mu2e Interface - Basic Engineering Complete | milestone | 0d | 2014-07-18 A | 2014-07-18 A | 215 | 100% |  | 2014-07-18 | 2014-07-18 | 0d |  |  |  |  |  |  |  |  |  |  |  |  |  |  |  |  |  |
| 217 | Cryo1.05.01.03 | Mu2e Interface - Detailed Engineering |  | 100d | 2014-07-21 A | 2014-12-10 | 216 | 8% | 92d | 2014-07-21 | 2014-12-10 | 100d | 113d | 0d |  | FNAD_CRYO_EN [70%] | 560h | 44.8h | 24,046.4 | 24,046.4 | 1,923.71 | +Cryo Mu2e Interface Connection BOE | Beams 4395 | Cryo1.05.01 |  | A1301.05.01 | A1301.05.01 - Mu2e Interface Connection | 2700 |  |
| 218 | Cryo1.05.01.04 | Mu2e Interface - Design/Drafting |  | 80d | 2014-12-11 | 2015-04-08 | 217 |  |  | 2014-12-11 | 2015-04-08 | 80d | 113d | 0d |  | FNAD_MECH_DRAFTER [181.2%] | 1160h |  | 33,500.8 | 33,500.8 |  | +Cryo Mu2e Interface Connection BOE | Beams 4395 | Cryo1.05.01 |  | A1301.05.01 | A1301.05.01 - Mu2e Interface Connection | 2701 |  |
| 219 | Cryo1.05.01.05 | Mu2e Interface - Drawings Ready | milestone | 0d | 2015-04-08 | 2015-04-08 | 218 |  |  | 2015-04-08 | 2015-04-08 | 0d | 113d | 0d |  |  |  |  |  |  |  |  |  |  |  |  |  |  |  |
| 220 | Cryo1.05.01.06 | Mu2e Interface - Prep Req & Process PO for Parts |  | 60d | 2015-04-09 | 2015-07-02 | 219 |  |  | 2015-04-09 | 2015-07-02 | 60d | 113d | 0d |  | FNAD_CRYO_EN [3%] | 16h |  | 687.04 | 687.04 |  | +Cryo Mu2e Interface Connection BOE | Beams 4395 | Cryo1.05.01 |  | A1301.05.01 | A1301.05.01 - Mu2e Interface Connection | 2606 |  |
| 221 | Cryo1.05.01.07 | Mu2e Interface - 1st Award PO |  | 1d | 2015-07-06 | 2015-07-06 | 220 |  |  | 2015-07-06 | 2015-07-06 | 1d | 113d | 0d |  |  |  |  |  |  |  | +Cryo Mu2e Interface Connection BOE | Beams 4395 | Cryo1.05.01 |  | A1301.05.01 | A1301.05.01 - Mu2e Interface Connection | 2607 |  |
| 222 | Cryo1.05.01.08 | Mu2e Interface - 1st Procured Items Delivered |  | 120d | 2015-09-01 | 2016-02-26 | 221FS+40d |  |  | 2015-09-01 | 2016-02-26 | 120d | 113d | 91d |  | FN_MS_STND_FY13 |  |  | 300,841 | 300,841 |  | +Cryo Mu2e Interface Connection BOE | Beams 4395 | Cryo1.05.01 |  | A1301.05.01 | A1301.05.01 - Mu2e Interface Connection | 2608 |  |
| 223 | Cryo1.05.01.09 | Mu2e Interface - 2nd Award PO |  | 1d | 2015-10-01 | 2015-10-01 | 10 |  |  | 2015-10-01 | 2015-10-01 | 1d | 22d | 0d |  |  |  |  |  |  |  | +Cryo Mu2e Interface Connection BOE | Beams 4395 | Cryo1.05.01 |  | A1301.05.01 | A1301.05.01 - Mu2e Interface Connection | 2834 |  |
| 224 | Cryo1.05.01.10 | Mu2e Interface - 2nd Procured Items Delivered |  | 120d | 2015-12-01 | 2016-05-23 | 223FS+40d |  |  | 2015-12-01 | 2016-05-23 | 120d | 22d | 0d |  | FN_MS_STND_FY13 |  |  | 300,000 | 300,000 |  |  |  | Cryo1.05.01 |  | A1301.05.01 | A1301.05.01 - Mu2e Interface Connection | 2833 |  |
| 225 | Cryo1.05.01.11 | Mu2e Interface - Fabrication |  | 60d | 2016-07-07 | 2016-09-29 | 222, 224FF+90d |  |  | 2016-07-07 | 2016-09-29 | 60d | 22d | 0d |  | FNAD_CRYO_TECH [608.3%]; FNAD_CRYO_EN [40%] | 3112h |  | 98,443.28 | 98,443.28 |  | +Cryo Mu2e Interface Connection BOE | Beams 4395 | Cryo1.05.01 |  | A1301.05.01 | A1301.05.01 - Mu2e Interface Connection | 2739 |  |
| 226 | Cryo1.05.01.12 | Mu2e Interface - Installation |  | 120d | 2016-09-30 | 2017-03-27 | 225, 153 |  |  | 2016-09-30 | 2017-03-27 | 120d | 22d | 0d |  | FNAD_CRYO_TECH [304.2%]; FNAD_CRYO_EN [20%] | 3112h |  | 98,443.28 | 98,443.28 |  | +Cryo Mu2e Interface Connection BOE | Beams 4395 | Cryo1.05.01 |  | A1301.05.01 | A1301.05.01 - Mu2e Interface Connection | 2714 |  |
| 227 | Cryo1.05.01.13 | Mu2e Interface - Task Management |  | 60d | 2016-09-30 | 2016-12-28 | 226SS |  |  | 2016-09-30 | 2016-12-28 | 60d | 82d | 60d |  | FNAD_CRYO_TECH | 40h |  | 1,235.6 | 1,235.6 |  | +Cryo Mu2e Interface Connection BOE | Beams 4395 | Cryo1.05.01 |  | A1301.05.01 | A1301.05.01 - Mu2e Interface Connection | 2738 |  |
| 228 | Cryo1.05.01.14 | Mu2e is connected | milestone | 0d | 2017-03-27 | 2017-03-27 | 226, 227 |  |  | 2017-03-27 | 2017-03-27 | 0d | 22d | 0d |  |  |  |  |  |  |  |  |  |  | Successor? |  |  |  |  |
| 229 | Cryo1.05.02 | g-2 Interface Connection |  | 24d | 2013-08-19 A | 2013-09-20 A |  | 100% |  | 2013-08-19 | 2013-09-20 | 24d |  |  | start no earlier than 2013-08-19 | FNAD_CRYO_EN [88.5%] | 170h | 170h | 8,724.4 | 8,724.4 | 8,724.4 | +Cryo Mu2e Interface Connection BOE | Beams 4395 | Cryo1.05.02 |  | A1301.05.02 | A1301.05.02 - g-2 Interface Connection | 2881 |  |
| 230 | Cryo1.06 | Cryo Safety Documents |  | 231d | 2013-10-01 A | 2014-09-02 A | 58FF | 100% |  | 2013-10-01 | 2014-09-02 | 231d |  |  |  | FNAD_CRYO_EN [63.2%] | 1168h | 1168h | 50,153.92 | 59,941.76 | 50,153.92 | Cryo Safety Documents BOE | Beams 4395 | Cryo1.06 |  | A1301.06 | A1301.06 - Cryo Safety Documents | 1126 |  |
| 231 | Cryo1.07 | **Testing/Checkout** |  | 646d | 2014-10-22 | 2017-05-22 |  |  |  | 2014-10-31 | 2017-05-22 | 639d | 7d |  |  |  | 1240h |  | 44,569.6 | 44,569.6 |  |  |  | Cryo1.07 |  | A1301.07 |  |  | ***Charge Code*** |
| 232 | Cryo1.07.01 | g-2 Cryo Checkout |  | 40d | 2014-10-22 | 2014-12-18 | 23 |  |  | 2014-10-31 | 2015-01-02 | 40d | 7d | 0d |  | FNAD_CRYO_EN [81.2%]; FNAD_CRYO_TECH [112.5%] | 620h |  | 22,284.8 | 22,284.8 |  | Cryo Testing_Checkout BOE | Beams 4395 | Cryo1.07 |  | A1301.07 | A1301.07 - Testing/Checkout | 1131 |  |
| 233 | Cryo1.07.02 | Mu2e Cryo Checkout |  | 40d | 2017-03-28 | 2017-05-22 | 228 |  |  | 2017-03-28 | 2017-05-22 | 40d | 22d | 0d |  | FNAD_CRYO_EN [81.2%]; FNAD_CRYO_TECH [112.5%] | 620h |  | 22,284.8 | 22,284.8 |  | Cryo Testing_Checkout BOE | Beams 4395 | Cryo1.07 |  | A1301.07 | A1301.07 - Testing/Checkout | 2824 |  |
| 234 | Cryo1.07.03 | Mu2e ORC | milestone | 0d | 2017-05-22 | 2017-05-22 | 233 |  |  | 2017-05-22 | 2017-05-22 | 0d | 22d | 0d |  |  |  |  |  |  |  |  |  |  |  |  |  |  |  |
| 235 | Cryo1.07.04 | g-2 ORC | milestone | 0d | 2014-12-18 | 2014-12-18 | 232 |  |  | 2015-01-02 | 2015-01-02 | 0d | 7d |  |  |  |  |  |  |  |  |  |  |  |  |  |  |  |  |
| 236 | Cryo1.08 | Cryo g-2 Acceptance Tests |  | 20d | 2014-09-24 A | 2014-10-21 | 102FF+15d, 64 | 10% | 18d | 2014-09-29 | 2014-10-24 | 20d | 47d | 40d |  | FNAD_CRYO_EN [151.9%]; FNAD_CRYO_TECH [276.9%]; FN_MS_STND_FY13 | 686h | 68.6h | 57,717.69 | 57,717.69 | 5,771.77 | Cryo g-2 Acceptance Tests BOE | Beams 4395 | Cryo1.08 | Successor? Labor? | A1301.08 | A1301.08 - Cryo g-2 Acceptance Tests | 1134 | ***Charge Code*** |
| 237 | Cryo1.09 | Cryo Mu2e Acceptance Tests |  | 20d | 2017-03-28 | 2017-04-24 | 228 |  |  | 2017-03-28 | 2017-04-24 | 20d | 42d | 0d |  | FNAD_CRYO_EN [151.9%]; FNAD_CRYO_TECH [276.9%]; FN_MS_STND_FY13 | 686h |  | 40,918.69 | 40,918.69 |  | Cryo Mu2e Acceptance Tests BOE | Beams 4395 | Cryo1.09 |  | A1301.09 | A1301.09 - Cryo Mu2e Acceptance Tests | 2611 | ***Charge Code*** |
| 238 | Cryo1.10 | Safety documents are completed | milestone | 0d | 2014-09-02 A | 2014-09-02 A | 230 | 100% |  | 2014-09-02 | 2014-09-02 | 0d |  |  |  |  |  |  |  |  |  |  |  |  | Successor? |  |  |  |  |
| 239 | Cryo1.11 | g-2 Checkout complete | milestone | 0d | 2014-12-18 | 2014-12-18 | 232, 236 |  |  | 2015-01-02 | 2015-01-02 | 0d | 7d | 0d |  |  |  |  |  |  |  |  |  |  | Successor? |  |  |  |  |
| 240 | Cryo1.12 | Mu2e Checkout complete | milestone | 0d | 2017-05-22 | 2017-05-22 | 237, 233 |  |  | 2017-05-22 | 2017-05-22 | 0d | 22d | 0d |  |  |  |  |  |  |  |  |  |  |  |  |  |  |  |

Notes:
- 211: Electrician @99 hours X $101/hour = $10,000.
